# BASICO

Schedule from MS Project, 2014-11-04 to 2016-02-15, status date 2015-01-26, A marks actual dates.

## Calendars

- Estándar: Mon-Fri 09:00-13:00, 15:00-19:00; Sat-Sun off.
- CALENDARIO DE TRABAJO MONTERESERVA: Mon-Fri 09:00-13:00, 15:00-19:00; Sat-Sun off. Exceptions (off unless hours are given): 2014-11-01 to 2016-12-31 09:00-13:00, 15:00-19:00 (TRABAJO LOS SABADOS, recurring), 2014-11-17 (NOVIEMBRE 17 DEL 2014), 2014-12-08 (DICIEMBRE 08 DEL 2014), 2014-12-22 to 2015-01-04 (ULTIMA SEMANA DE DICEIMBRE DEL 2014, PRIMERA ENERO DEL 2015), 2015-01-12 (ENERO 12 DEL 2015), 2015-03-23 (MARZO 23 DEL 2015), 2015-03-30 to 2015-04-05 (SEMANA SANTA 2015), 2015-05-01 (MAYO 01 DEL 2015), 2015-05-18 (MAYO 18 DEL 2015), 2015-06-08 (JUNIO 08 DEL 2015), 2015-06-15 (JUNIO 15 DEL 2015), 2015-06-29 (JUNIO 29 DEL 2015), 2015-07-20 (JULIO 20 DEL 2015), 2015-08-07 (AGOSTO 07 DEL 2015), 2015-08-17 (AGOSTO17 DEL 2015), 2015-10-12 (OCTUBRE 12 DEL 2015), 2015-11-02 (NOVIEMBRE 02 DEL 2015), 2015-11-16 (NOVIEMBRE 16 DEL 2015), 2015-12-08 (DICIEMBRE 08 DEL 2015), 2015-12-21 to 2016-01-03 (DICIEMBRE 25 DEL 2015), 2016-01-11 (ENERO 11 DEL 2016).
- DIAS CALENDARIO: Mon-Fri 09:00-13:00, 15:00-19:00; Sat-Sun off.
- DIAS CALENDARIO 2: Mon-Fri 09:00-13:00, 15:00-19:00; Sat-Sun off. Exceptions (off unless hours are given): 2013-08-01 to 2015-01-31 09:00-13:00, 15:00-19:00 (DIAS CALENDARIO).

## Schedule

| ID | WBS | Task | Duration | Start | Finish | Predecessors | Complete | Remaining | Baseline start | Baseline finish | Baseline duration | Total slack | Constraint | Calendar | Text1 | Text5 | Text6 | Text2 |
| --- | --- | --- | --- | --- | --- | --- | --- | --- | --- | --- | --- | --- | --- | --- | --- | --- | --- | --- |
| 1 | 1 | **MONTERESERVA TORRE 8** | 359.52d | 2014-11-04 A | 2016-02-15 |  | 3% | 348.34d | 2014-11-04 | 2016-02-08 | 355d | 0d |  | DIAS CALENDARIO 2 | 3% | 0% | 6% |  |
| 2 | 1.1 | **PRELIMINARES DE OBRA** | 87.68d | 2014-11-04 A | 2015-01-30 |  | 89% | 10.08d | 2014-11-04 | 2015-01-28 | 86d | 0d |  | DIAS CALENDARIO 2 | 100% | 0% | 98% | 84% |
| 3 | 1.1.1 | CONTRATACION EXCAVACION MECANICA | 6d | 2014-11-04 A | 2014-11-10 A |  | 100% |  | 2014-11-04 | 2014-11-10 | 6d |  | start no earlier than 2014-11-04 | CALENDARIO DE TRABAJO MONTERESERVA |  | 0% | 100% |  |
| 4 | 1.1.2 | BANCO DE HIERRO | 6d | 2014-11-10 A | 2014-11-15 A |  | 100% |  | 2014-11-10 | 2014-11-15 | 6d |  |  | CALENDARIO DE TRABAJO MONTERESERVA | 100% | 0% | 100% | 100% |
| 5 | 1.1.3 | LOCALIZACION DE OBRA | 6d | 2014-11-10 A | 2014-11-15 A |  | 100% |  | 2014-11-10 | 2014-11-15 | 6d |  |  | CALENDARIO DE TRABAJO MONTERESERVA | 100% | 0% | 100% | 100% |
| 6 | 1.1.4 | PEDIDO DE HIERRO ARRANQUE DE COLUMNAS | 2d | 2015-01-13 A | 2015-01-27 |  | 66% | 0.68d | 2015-01-13 | 2015-01-14 | 2d | 0d | start no earlier than 2015-01-13 | CALENDARIO DE TRABAJO MONTERESERVA |  | 0% | 100% |  |
| 7 | 1.1.5 | LLEGADA ACERO A OBRA | 6d | 2015-01-15 A | 2015-01-30 | 6 | 50% | 3d | 2015-01-15 | 2015-01-21 | 6d | 0d |  | CALENDARIO DE TRABAJO MONTERESERVA |  | 0% | 100% |  |
| 8 | 1.1.6 | FIGURACION ACERO COLUMNAS Y ZAPATAS | 6d | 2015-01-22 A | 2015-01-28 A | 7 | 100% |  | 2015-01-22 | 2015-01-28 | 6d |  |  | CALENDARIO DE TRABAJO MONTERESERVA |  | 0% | 71% |  |
| 9 | 1.2 | **ESTRUCTURAS** | 197d | 2014-11-11 A | 2015-07-11 |  | 22% | 153.72d | 2014-11-11 | 2015-07-04 | 192d | 155.52d |  | DIAS CALENDARIO 2 | 7% | 0% | 33% | 2% |
| 10 | 1.2.1 | **ESTRUCTURA** | 184.52d | 2014-11-11 A | 2015-06-24 |  | 26% | 135.98d | 2014-11-11 | 2015-06-17 | 180d | 168d |  | DIAS CALENDARIO 2 | 9% | 0% | 35% | 2% |
| 11 | 1.2.1.1 | **ESTRUCTURAS HASTA NIVEL - 3.80 SOTANO 2. ( 101 Y 102)** | 122d | 2014-11-11 A | 2015-03-28 |  | 43% | 69.95d | 2014-11-11 | 2015-03-20 | 117d | 230.52d |  | DIAS CALENDARIO 2 | 29% | 0% | 59% | 7% |
| 12 | 1.2.1.1.1 | **-14.90** | 91.52d | 2014-11-11 A | 2015-02-13 |  | 61% | 35.36d | 2014-11-11 | 2015-02-06 | 87d | 0d |  | DIAS CALENDARIO 2 |  | 0% | 88% |  |
| 13 | 1.2.1.1.1.1 | EXCAVACION MECANICA 1- NIVEL -14.90 | 6d | 2014-11-11 A | 2014-11-18 A | 3 | 100% |  | 2014-11-11 | 2014-11-18 | 6d |  | start no earlier than 2014-01-13 | CALENDARIO DE TRABAJO MONTERESERVA |  | 0% | 100% |  |
| 14 | 1.2.1.1.1.2 | EXCAVACION CAISSONS Y ZAPATAS ( 3 CAISSONS ) | 7d | 2014-11-19 A | 2014-11-26 A | 5, 13 | 100% |  | 2014-11-19 | 2014-11-26 | 7d |  |  | CALENDARIO DE TRABAJO MONTERESERVA | 59% | 0% | 100% | 18% |
| 15 | 1.2.1.1.1.3 | FUNDICION CAISSONS Y ZAPATAS ( 3 CAISSONS ) | 10d | 2014-11-20 A | 2014-12-01 A | 14FF+4d | 100% |  | 2014-11-20 | 2014-12-01 | 10d |  |  | CALENDARIO DE TRABAJO MONTERESERVA |  | 0% | 100% |  |
| 16 | 1.2.1.1.1.4 | VIGAS DE CIIMENTACION NIVEL -14.90 | 4d | 2015-01-22 A | 2015-02-02 | 15FF+3d, 7 | 54% | 1.84d | 2015-01-22 | 2015-01-26 | 4d | 0d |  | CALENDARIO DE TRABAJO MONTERESERVA |  | 0% | 100% |  |
| 17 | 1.2.1.1.1.5 | COLUMNAS -14.90 A -11.90 ( 10 COLUMNAS ) | 4d | 2015-02-02 | 2015-02-06 | 16 |  |  | 2015-01-27 | 2015-01-30 | 4d | 0d |  | CALENDARIO DE TRABAJO MONTERESERVA |  | 0% | 0% |  |
| 18 | 1.2.1.1.1.6 | MURO DE CONTENCION M4 - MC2 | 10d | 2015-02-02 | 2015-02-13 | 17SS |  |  | 2015-01-27 | 2015-02-06 | 10d | 0d |  | CALENDARIO DE TRABAJO MONTERESERVA |  | 0% | 0% |  |
| 19 | 1.2.1.1.2 | **-11.90** | 80.52d | 2014-12-01 A | 2015-02-26 |  | 51% | 39.28d | 2014-12-01 | 2015-02-19 | 76d | 0d |  | DIAS CALENDARIO 2 |  | 0% | 70% |  |
| 20 | 1.2.1.1.2.1 | EXCAVACION MECANICA 2- NIVEL -10.80 | 3d | 2014-12-01 A | 2014-12-03 A | 15FS-1d | 100% |  | 2014-12-01 | 2014-12-03 | 3d |  |  | CALENDARIO DE TRABAJO MONTERESERVA |  | 0% | 100% |  |
| 21 | 1.2.1.1.2.2 | EXCAVACION CAISSONS Y ZAPATAS ( 7 CAISSONS Y ZAPATA CENTRAL. ) | 12d | 2015-01-05 A | 2015-01-19 A | 20FF, 14 | 100% |  | 2015-01-05 | 2015-01-19 | 12d |  | must finish on 2015-01-19 | CALENDARIO DE TRABAJO MONTERESERVA | 59% | 0% | 100% | 18% |
| 22 | 1.2.1.1.2.3 | FUNDICION CAISSONS Y ZAPATA CENTRAL | 6d | 2015-01-14 A | 2015-01-20 A | 21FF+1d | 100% |  | 2015-01-14 | 2015-01-20 | 6d |  |  | CALENDARIO DE TRABAJO MONTERESERVA |  | 0% | 100% |  |
| 23 | 1.2.1.1.2.4 | VIGAS DE CIIMENTACION Y AEREAS NIVEL -11.90 | 6d | 2015-02-10 | 2015-02-17 | 22FF+3d, 16, 17FF+3d, 18FF+3d |  |  | 2015-02-04 | 2015-02-10 | 6d | 0d |  | CALENDARIO DE TRABAJO MONTERESERVA |  | 0% | 0% |  |
| 24 | 1.2.1.1.2.5 | COLUMNAS -11.90 A - 7.85 ( 16 COLUMNAS ) | 6d | 2015-02-17 | 2015-02-24 | 23, 17FF+3d, 18FF+3d |  |  | 2015-02-11 | 2015-02-17 | 6d | 0d |  | CALENDARIO DE TRABAJO MONTERESERVA |  | 0% | 0% |  |
| 25 | 1.2.1.1.2.6 | MUROS DE CONTENCION MC3 | 8d | 2015-02-17 | 2015-02-26 | 24SS |  |  | 2015-02-11 | 2015-02-19 | 8d | 0d |  | CALENDARIO DE TRABAJO MONTERESERVA |  | 0% | 0% |  |

| ID | WBS | Task | Duration | Start | Finish | Predecessors | Complete | Remaining | Baseline start | Baseline finish | Baseline duration | Total slack | Free slack | Constraint | Calendar | Text5 | Text6 | Text1 | Text2 |
| --- | --- | --- | --- | --- | --- | --- | --- | --- | --- | --- | --- | --- | --- | --- | --- | --- | --- | --- | --- |
| 26 | 1.2.1.1.3 | **-7.85** | 52.52d | 2015-01-09 A | 2015-03-13 |  | 37% | 33.04d | 2015-01-20 | 2015-03-06 | 37d | 0d |  |  | DIAS CALENDARIO 2 | 0% | 15% |  |  |
| 27 | 1.2.1.1.3.1 | EXCAVACION MECANICA 3 - NIVEL -7.30 | 6d | 2015-01-20 A | 2015-01-26 A | 22FS-1d | 100% |  | 2015-01-20 | 2015-01-26 | 6d |  |  | start no earlier than 2015-01-05 | CALENDARIO DE TRABAJO MONTERESERVA | 0% | 100% |  |  |
| 28 | 1.2.1.1.3.2 | EXCAVACION CAISSONS Y ZAPATAS ( 4 CAISSONS Y 2 ZAPATAS ) | 8d | 2015-01-09 A | 2015-01-19 A | 27, 21 | 100% |  | 2015-01-27 | 2015-02-04 | 8d |  |  |  | CALENDARIO DE TRABAJO MONTERESERVA | 0% | 0% | 59% | 18% |
| 29 | 1.2.1.1.3.3 | FUNDICION CAISSONS Y ZAPATAS | 8d | 2015-01-22 A | 2015-01-30 | 28FF+1d | 80% | 1.6d | 2015-01-28 | 2015-02-05 | 8d | 11.52d | 9.52d |  | CALENDARIO DE TRABAJO MONTERESERVA | 0% | 0% |  |  |
| 30 | 1.2.1.1.3.4 | VIGAS DE CIIMENTACION Y AEREAS NIVEL -7.85 | 12d | 2015-02-13 | 2015-02-27 | 29, 25FF+1d, 24FF+1d, 7 |  |  | 2015-02-07 | 2015-02-20 | 12d | 0d |  |  | CALENDARIO DE TRABAJO MONTERESERVA | 0% | 0% |  |  |
| 31 | 1.2.1.1.3.5 | COLUMNAS -7.85 A - 3.80 ( 17 COLUMNAS ) | 9d | 2015-02-27 | 2015-03-10 | 30, 24FF+3d, 25FF+3d |  |  | 2015-02-21 | 2015-03-03 | 9d | 0d |  |  | CALENDARIO DE TRABAJO MONTERESERVA | 0% | 0% |  |  |
| 32 | 1.2.1.1.3.6 | MURO DE CONTENCION MC 1 EJE 1 | 12d | 2015-02-27 | 2015-03-13 | 31SS |  |  | 2015-02-21 | 2015-03-06 | 12d | 0d |  |  | CALENDARIO DE TRABAJO MONTERESERVA | 0% | 0% |  |  |
| 33 | 1.2.1.1.4 | **-PLACA -3.80 ( PISO SOTANO 2)** | 20.48d | 2015-02-27 | 2015-03-28 |  |  |  | 2015-02-21 | 2015-03-20 | 20d | 6d |  |  | DIAS CALENDARIO 2 | 0% | 0% |  |  |
| 34 | 1.2.1.1.4.1 | EXCAVACION MECANICA 3 - PARA NIVEL -3.80 | 3d | 2015-02-27 | 2015-03-03 | 29FS-1d, 30 |  |  | 2015-02-21 | 2015-02-24 | 3d | 267d |  |  | CALENDARIO DE TRABAJO MONTERESERVA | 0% | 0% |  |  |
| 35 | 1.2.1.1.4.2 | COMPLEMENTOS VIGAS DE CIIMENTACION -7.85 | 4d | 2015-02-27 | 2015-03-04 | 30 |  |  | 2015-02-21 | 2015-02-25 | 4d | 8d | 7d |  | CALENDARIO DE TRABAJO MONTERESERVA | 0% | 0% |  |  |
| 36 | 1.2.1.1.4.3 | PLACA NIVEL -3.80 ( INCLUYE SENCILLAS Y DOBLES ALTURAS) | 12d | 2015-03-13 | 2015-03-28 | 31, 32, 35 |  |  | 2015-03-07 | 2015-03-20 | 12d | 0d |  |  | CALENDARIO DE TRABAJO MONTERESERVA | 0% | 0% |  |  |
| 37 | 1.2.1.2 | **PANTALLAS COLUMNAS Y LOSA N -0.05 S1 ( 201 Y 202)** | 11.52d | 2015-03-28 | 2015-04-14 |  |  |  | 2015-03-21 | 2015-04-07 | 12d | 0d |  |  | DIAS CALENDARIO 2 | 0% | 0% | 0% | 0% |
| 38 | 1.2.1.2.1 | PANTALLAS Y COLUMNAS ( 18 ELEMENTOS) | 5d | 2015-03-28 | 2015-04-10 | 36 |  |  | 2015-03-21 | 2015-03-27 | 5d | 0d |  |  | CALENDARIO DE TRABAJO MONTERESERVA | 0% | 0% |  |  |
| 39 | 1.2.1.2.2 | LOSA NIVEL -0.05 ( 201 Y 202) | 8d | 2015-03-28 | 2015-04-14 | 38FF+3d |  |  | 2015-03-21 | 2015-04-07 | 8d | 0d |  |  | CALENDARIO DE TRABAJO MONTERESERVA | 0% | 0% | 0% | 0% |
| 40 | 1.2.1.3 | **PANTALLAS COLUMNAS Y LOSA N + 3.70 P3, 301 Y 302.** | 7d | 2015-04-14 | 2015-04-23 |  |  |  | 2015-04-08 | 2015-04-16 | 7d | 0d |  |  | DIAS CALENDARIO 2 | 0% | 0% | 0% | 0% |
| 41 | 1.2.1.3.1 | PANTALLAS Y COLUMNAS | 5d | 2015-04-14 | 2015-04-20 | 39 |  |  | 2015-04-08 | 2015-04-13 | 5d | 0d |  |  | CALENDARIO DE TRABAJO MONTERESERVA | 0% | 0% | 0% | 0% |
| 42 | 1.2.1.3.2 | LOSA NIVEL + 3.70 ( 301 Y 302 ) 360 M2 APROX. | 7d | 2015-04-15 | 2015-04-23 | 41FF+3d |  |  | 2015-04-09 | 2015-04-16 | 7d | 0d |  |  | CALENDARIO DE TRABAJO MONTERESERVA | 0% | 0% | 0% | 0% |
| 43 | 1.2.1.4 | **PANTALLAS COLUMNAS Y LOSA N + 7.45 ( PISO 4 ) 401 Y 402** | 7d | 2015-04-23 | 2015-05-04 |  |  |  | 2015-04-17 | 2015-04-25 | 6d | 0d |  |  | DIAS CALENDARIO 2 | 0% | 0% | 0% | 0% |
| 44 | 1.2.1.4.1 | PANTALLAS Y COLUMNAS | 5d | 2015-04-23 | 2015-04-29 | 42 |  |  | 2015-04-17 | 2015-04-22 | 5d | 0d |  |  | CALENDARIO DE TRABAJO MONTERESERVA | 0% | 0% | 0% | 0% |
| 45 | 1.2.1.4.2 | LOSA NIVEL + 7.45 ( 401 Y 402 ) 360 M2 APROX. | 7d | 2015-04-24 | 2015-05-04 | 44FF+3d |  |  | 2015-04-18 | 2015-04-25 | 7d | 0d |  |  | CALENDARIO DE TRABAJO MONTERESERVA | 0% | 0% | 0% | 0% |
| 46 | 1.2.1.5 | **PANTALLAS COLUMNAS Y LOSA N + 11.20 ( PISO 5 )501 Y 502** | 7d | 2015-05-04 | 2015-05-13 |  |  |  | 2015-04-27 | 2015-05-06 | 8d | 0d |  |  | DIAS CALENDARIO 2 | 0% | 0% | 0% | 0% |
| 47 | 1.2.1.5.1 | PANTALLAS Y COLUMNAS | 5d | 2015-05-04 | 2015-05-09 | 45 |  |  | 2015-04-27 | 2015-05-02 | 5d | 0d |  |  | CALENDARIO DE TRABAJO MONTERESERVA | 0% | 0% | 0% | 0% |
| 48 | 1.2.1.5.2 | LOSA NIVEL+11.20 ( 501 Y 502 ) 360 M2 APROX. | 7d | 2015-05-05 | 2015-05-13 | 47FF+3d |  |  | 2015-04-28 | 2015-05-06 | 7d | 0d |  |  | CALENDARIO DE TRABAJO MONTERESERVA | 0% | 0% | 0% | 0% |
| 49 | 1.2.1.6 | **PANTALLAS COLUMNAS Y LOSA N + 14.95 ( PISO 6 ) BAJILLOS P6** | 7.48d | 2015-05-13 | 2015-05-23 |  |  |  | 2015-05-07 | 2015-05-15 | 7d | 0d |  |  | DIAS CALENDARIO 2 | 0% | 0% | 0% | 0% |
| 50 | 1.2.1.6.1 | PANTALLAS Y COLUMNAS | 5d | 2015-05-13 | 2015-05-20 | 48 |  |  | 2015-05-07 | 2015-05-12 | 5d | 0d |  |  | CALENDARIO DE TRABAJO MONTERESERVA | 0% | 0% | 0% | 0% |
| 51 | 1.2.1.6.2 | LOSA NIVEL + 14.95 ( BAJILLOS 601 Y 602 ) 360 M2 APROX. | 7d | 2015-05-14 | 2015-05-23 | 50FF+3d |  |  | 2015-05-08 | 2015-05-15 | 7d | 0d |  |  | CALENDARIO DE TRABAJO MONTERESERVA | 0% | 0% | 0% | 0% |

| ID | WBS | Task | Duration | Start | Finish | Predecessors | Baseline start | Baseline finish | Baseline duration | Total slack | Free slack | Calendar | Text1 | Text2 | Text5 | Text6 |
| --- | --- | --- | --- | --- | --- | --- | --- | --- | --- | --- | --- | --- | --- | --- | --- | --- |
| 52 | 1.2.1.7 | **PANTALLAS COLUMNAS Y LOSA N + 18.70 ( PISO 6 ) ALTILLOS 601 Y 602** | 7.52d | 2015-05-23 | 2015-06-03 | 51 | 2015-05-16 | 2015-05-27 | 8d | 0d |  | DIAS CALENDARIO 2 | 0% | 0% | 0% | 0% |
| 53 | 1.2.1.7.1 | PANTALLAS Y COLUMNAS | 5d | 2015-05-23 | 2015-05-29 |  | 2015-05-16 | 2015-05-22 | 5d | 0d |  | CALENDARIO DE TRABAJO MONTERESERVA | 0% | 0% | 0% | 0% |
| 54 | 1.2.1.7.2 | LOSA NIVEL + 18.70 ( ALTILLOS 601 Y 602 ) 360 M2 APROX. | 7d | 2015-05-26 | 2015-06-03 | 53FF+4d | 2015-05-20 | 2015-05-27 | 7d | 0d |  | CALENDARIO DE TRABAJO MONTERESERVA | 0% | 0% | 0% | 0% |
| 55 | 1.2.1.8 | **PANTALLAS COLUMNAS Y CUBIERTA + 22.45** | 9d | 2015-06-03 | 2015-06-16 |  | 2015-05-28 | 2015-06-06 | 7d | 1d |  | DIAS CALENDARIO 2 | 0% | 0% | 0% | 0% |
| 56 | 1.2.1.8.1 | PANTALLAS Y COLUMNAS | 6d | 2015-06-03 | 2015-06-11 | 54 | 2015-05-28 | 2015-06-03 | 6d | 1d | 0d | CALENDARIO DE TRABAJO MONTERESERVA | 0% | 0% | 0% | 0% |
| 57 | 1.2.1.8.2 | LOSA CUBIERTA N+22.45 | 7d | 2015-06-05 | 2015-06-16 | 56FF+3d | 2015-05-30 | 2015-06-06 | 7d | 1d | 0d | CALENDARIO DE TRABAJO MONTERESERVA | 0% | 0% | 0% | 0% |
| 58 | 1.2.1.9 | **PANTALLAS COLUMNAS Y CUBIERTA ESCALERAS** | 6d | 2015-06-16 | 2015-06-24 |  | 2015-06-09 | 2015-06-17 | 7d | 12.48d |  | DIAS CALENDARIO 2 | 0% | 0% | 0% | 0% |
| 59 | 1.2.1.9.1 | PANTALLAS Y COLUMNAS | 4d | 2015-06-16 | 2015-06-20 | 57 | 2015-06-09 | 2015-06-12 | 4d | 14d | 0d | CALENDARIO DE TRABAJO MONTERESERVA | 0% | 0% | 0% | 0% |
| 60 | 1.2.1.9.2 | LOSA MAQUINAS | 7d | 2015-06-16 | 2015-06-24 | 59FF+3d | 2015-06-09 | 2015-06-17 | 7d | 14d | 0d | CALENDARIO DE TRABAJO MONTERESERVA | 0% | 0% | 0% | 0% |
| 61 | 1.2.2 | **DESCIMBRADA DE PLACAS** | 63.48d | 2015-04-14 | 2015-07-11 |  | 2015-04-08 | 2015-07-04 | 63d | 15.52d |  | DIAS CALENDARIO 2 | 0% | 0% | 0% | 0% |
| 62 | 1.2.2.1 | DESCIMBRADO NIVEL -3.80 | 6d | 2015-04-14 | 2015-04-21 | 39 | 2015-04-08 | 2015-04-14 | 6d | 47d | 28.48d | CALENDARIO DE TRABAJO MONTERESERVA | 0% | 0% | 0% | 0% |
| 63 | 1.2.2.2 | DESCIMBRADO NIVEL-0.05 | 6d | 2015-04-23 | 2015-04-30 | 42 | 2015-04-17 | 2015-04-23 | 6d | 17d | 0d | CALENDARIO DE TRABAJO MONTERESERVA | 0% | 0% | 0% | 0% |
| 64 | 1.2.2.3 | DESCIMBRADO NIVEL +3.70 | 6d | 2015-05-04 | 2015-05-11 | 45 | 2015-04-27 | 2015-05-04 | 6d | 9d | 0d | CALENDARIO DE TRABAJO MONTERESERVA | 0% | 0% | 0% | 0% |
| 65 | 1.2.2.4 | DESCIMBRADO NIVEL+7.45 | 6d | 2015-05-13 | 2015-05-21 | 48 | 2015-05-07 | 2015-05-13 | 6d | 2d | 0d | CALENDARIO DE TRABAJO MONTERESERVA | 0% | 0% | 0% | 0% |
| 66 | 1.2.2.5 | DESCIMBRADO NIVEL+11.20 | 6d | 2015-05-23 | 2015-05-30 | 51 | 2015-05-16 | 2015-05-23 | 6d | 3d | 0d | CALENDARIO DE TRABAJO MONTERESERVA | 0% | 0% | 0% | 0% |
| 67 | 1.2.2.6 | DESCIMBRADO NIVEL+14.95 | 6d | 2015-06-03 | 2015-06-11 | 54 | 2015-05-28 | 2015-06-03 | 6d | 0d |  | CALENDARIO DE TRABAJO MONTERESERVA | 0% | 0% | 0% | 0% |
| 68 | 1.2.2.7 | DESCIMBRADO NIVEL+18.70 | 6d | 2015-06-16 | 2015-06-23 | 57 | 2015-06-09 | 2015-06-16 | 6d | 1d | 0d | CALENDARIO DE TRABAJO MONTERESERVA | 0% | 0% | 0% | 0% |
| 69 | 1.2.2.8 | DESCIMBRADO NIVEL+ 22.45 | 6d | 2015-06-24 | 2015-07-02 | 68, 60 | 2015-06-18 | 2015-06-24 | 6d | 14d | 0d | CALENDARIO DE TRABAJO MONTERESERVA |  |  | 0% | 0% |
| 70 | 1.2.2.9 | DESCIMBRADO CUBIERTA ESCALERA | 2d | 2015-07-09 | 2015-07-11 | 57FS+12d, 69, 60FS+12d | 2015-07-03 | 2015-07-04 | 2d | 18d | 0d | CALENDARIO DE TRABAJO MONTERESERVA |  |  | 0% | 0% |
| 71 | 1.3 | **OBRA GRIS APARTAMENTOS** | 154d | 2015-04-30 | 2015-12-02 |  | 2015-04-24 | 2015-11-25 | 154d | 16d |  | DIAS CALENDARIO 2 | 0% | 0% | 0% | 0% |
| 72 | 1.3.1 | **PROLONGACIONES HIDRAULICAS** | 48d | 2015-04-30 | 2015-07-07 |  | 2015-04-24 | 2015-06-30 | 48d | 13d |  | DIAS CALENDARIO 2 | 0% | 0% | 0% | 0% |
| 73 | 1.3.1.1 | PROLONGACIONES HIDR. SOTANO | 4d | 2015-04-30 | 2015-05-06 | 63 | 2015-04-24 | 2015-04-28 | 4d | 17d | 7d | CALENDARIO DE TRABAJO MONTERESERVA | 0% | 0% | 0% | 0% |
| 74 | 1.3.1.2 | PROLONGACIONES HIDR. LOBBY | 4d | 2015-05-11 | 2015-05-15 | 63, 64 | 2015-05-05 | 2015-05-08 | 4d | 9d | 0d | CALENDARIO DE TRABAJO MONTERESERVA | 0% | 0% | 0% | 0% |
| 75 | 1.3.1.3 | PROLONGACIONES HIDR. P2 | 4d | 2015-05-21 | 2015-05-26 | 65 | 2015-05-14 | 2015-05-19 | 4d | 2d | 0d | CALENDARIO DE TRABAJO MONTERESERVA | 0% | 0% | 0% | 0% |
| 76 | 1.3.1.4 | PROLONGACIONES HIDR. P3 | 4d | 2015-05-30 | 2015-06-04 | 66 | 2015-05-25 | 2015-05-28 | 4d | 3d | 1d | CALENDARIO DE TRABAJO MONTERESERVA | 0% | 0% | 0% | 0% |
| 77 | 1.3.1.5 | PROLONGACIONES HIDR. P4 | 4d | 2015-06-11 | 2015-06-17 | 67 | 2015-06-04 | 2015-06-09 | 4d | 6d | 3d | CALENDARIO DE TRABAJO MONTERESERVA | 0% | 0% | 0% | 0% |
| 78 | 1.3.1.6 | PROLONGACIONES HIDR. P5 | 4d | 2015-06-23 | 2015-06-27 | 68 | 2015-06-17 | 2015-06-20 | 4d | 9d | 6.52d | CALENDARIO DE TRABAJO MONTERESERVA | 0% | 0% | 0% | 0% |
| 79 | 1.3.1.7 | PROLONGACIONES HIDR.P6 | 4d | 2015-07-02 | 2015-07-07 | 69 | 2015-06-25 | 2015-06-30 | 4d | 14d | 11d | CALENDARIO DE TRABAJO MONTERESERVA | 0% | 0% | 0% | 0% |

| ID | WBS | Task | Duration | Start | Finish | Predecessors | Baseline start | Baseline finish | Baseline duration | Total slack | Free slack | Calendar | Text1 | Text2 | Text5 | Text6 |
| --- | --- | --- | --- | --- | --- | --- | --- | --- | --- | --- | --- | --- | --- | --- | --- | --- |
| 80 | 1.3.2 | **PROLONGACIONES ELECTRICAS** | 48d | 2015-04-30 | 2015-07-07 |  | 2015-04-24 | 2015-06-30 | 48d | 16d |  | DIAS CALENDARIO 2 | 0% | 0% | 0% | 0% |
| 81 | 1.3.2.1 | PROLONGACIONES ELECTR. SOTANO | 4d | 2015-04-30 | 2015-05-06 | 63 | 2015-04-24 | 2015-04-28 | 4d | 17d | 7d | CALENDARIO DE TRABAJO MONTERESERVA | 0% | 0% | 0% | 0% |
| 82 | 1.3.2.2 | PROLONGACIONES ELECT. LOBBY | 4d | 2015-05-11 | 2015-05-15 | 64 | 2015-05-05 | 2015-05-08 | 4d | 19d | 15d | CALENDARIO DE TRABAJO MONTERESERVA | 0% | 0% | 0% | 0% |
| 83 | 1.3.2.3 | PROLONGACIONES ELECT. P2 | 4d | 2015-05-21 | 2015-05-26 | 65 | 2015-05-14 | 2015-05-19 | 4d | 11d | 8d | CALENDARIO DE TRABAJO MONTERESERVA | 0% | 0% | 0% | 0% |
| 84 | 1.3.2.4 | PROLONGACIONES ELECT. P3 | 4d | 2015-05-30 | 2015-06-04 | 66 | 2015-05-25 | 2015-05-28 | 4d | 15d | 12d | CALENDARIO DE TRABAJO MONTERESERVA | 0% | 0% | 0% | 0% |
| 85 | 1.3.2.5 | PROLONGACIONES ELECT. P4 | 4d | 2015-06-11 | 2015-06-17 | 67 | 2015-06-04 | 2015-06-09 | 4d | 18d | 14d | CALENDARIO DE TRABAJO MONTERESERVA | 0% | 0% | 0% | 0% |
| 86 | 1.3.2.6 | PROLONGACIONES ELECT. P5 | 4d | 2015-06-23 | 2015-06-27 | 68 | 2015-06-17 | 2015-06-20 | 4d | 21d | 17.52d | CALENDARIO DE TRABAJO MONTERESERVA | 0% | 0% | 0% | 0% |
| 87 | 1.3.2.7 | PROLONGACIONES ELECT. P6 | 4d | 2015-07-02 | 2015-07-07 | 69 | 2015-06-25 | 2015-06-30 | 4d | 26d | 21d | CALENDARIO DE TRABAJO MONTERESERVA | 0% | 0% | 0% | 0% |
| 88 | 1.3.3 | **PROLONGACIONES ELECTRICAS AEREAS** | 55d | 2015-04-30 | 2015-07-16 |  | 2015-04-24 | 2015-07-09 | 55d | 16d |  | DIAS CALENDARIO 2 | 0% | 0% | 0% | 0% |
| 89 | 1.3.3.1 | PROLONGACIONES ELECTR.AEREAS SOTANO | 4d | 2015-04-30 | 2015-05-06 | 63 | 2015-04-24 | 2015-04-28 | 4d | 17d | 7d | CALENDARIO DE TRABAJO MONTERESERVA | 0% | 0% | 0% | 0% |
| 90 | 1.3.3.2 | PROLONGACIONES ELECT.AEREAS LOBBY | 4d | 2015-05-11 | 2015-05-15 | 64 | 2015-05-05 | 2015-05-08 | 4d | 19d | 15d | CALENDARIO DE TRABAJO MONTERESERVA | 0% | 0% | 0% | 0% |
| 91 | 1.3.3.3 | PROLONGACIONES ELECT.AEREAS P2 | 4d | 2015-05-21 | 2015-05-26 | 65 | 2015-05-14 | 2015-05-19 | 4d | 11d | 8d | CALENDARIO DE TRABAJO MONTERESERVA | 0% | 0% | 0% | 0% |
| 92 | 1.3.3.4 | PROLONGACIONES ELECT.AEREAS P3 | 4d | 2015-05-30 | 2015-06-04 | 66 | 2015-05-25 | 2015-05-28 | 4d | 15d | 12d | CALENDARIO DE TRABAJO MONTERESERVA | 0% | 0% | 0% | 0% |
| 93 | 1.3.3.5 | PROLONGACIONES ELECT.AEREAS P4 | 4d | 2015-06-23 | 2015-06-27 | 68 | 2015-06-17 | 2015-06-20 | 4d | 9d | 6.52d | CALENDARIO DE TRABAJO MONTERESERVA | 0% | 0% | 0% | 0% |
| 94 | 1.3.3.6 | PROLONGACIONES ELECT.AEREAS P5 | 4d | 2015-07-02 | 2015-07-07 | 69 | 2015-06-25 | 2015-06-30 | 4d | 14d | 11d | CALENDARIO DE TRABAJO MONTERESERVA | 0% | 0% | 0% | 0% |
| 95 | 1.3.3.7 | PROLONGACIONES ELECT.AEREAS P6 | 4d | 2015-07-11 | 2015-07-16 | 70 | 2015-07-06 | 2015-07-09 | 4d | 18d | 14d | CALENDARIO DE TRABAJO MONTERESERVA | 0% | 0% | 0% | 0% |
| 96 | 1.3.4 | **MAMPOSTERIA INTERNA** | 70d | 2015-05-15 | 2015-08-21 |  | 2015-05-09 | 2015-08-13 | 69d | 1d |  | DIAS CALENDARIO 2 | 0% | 0% | 0% | 0% |
| 97 | 1.3.4.1 | MAMPOSTERIA INTERNA. SOTANO Y APARTAMENTOS 101 Y 102 | 12d | 2015-05-15 | 2015-05-30 | 73, 81, 89, 74 | 2015-05-09 | 2015-05-23 | 12d | 9d | 0d | CALENDARIO DE TRABAJO MONTERESERVA | 0% | 0% | 0% | 0% |
| 98 | 1.3.4.2 | MAMPOSTERIA INTERNA. LOBBY Y APTOS 201 Y 202 | 9d | 2015-05-26 | 2015-06-05 | 82FF, 90FF, 75 | 2015-05-20 | 2015-05-29 | 9d | 2d | 0d | CALENDARIO DE TRABAJO MONTERESERVA | 0% | 0% | 0% | 0% |
| 99 | 1.3.4.3 | MAMPOSTERIA INTERNA. 301 Y 302 | 12d | 2015-06-05 | 2015-06-22 | 98, 75, 83, 91, 76 | 2015-05-30 | 2015-06-13 | 12d | 2d | 0d | CALENDARIO DE TRABAJO MONTERESERVA | 0% | 0% | 0% | 0% |
| 100 | 1.3.4.4 | MAMPOSTERIA INTERNA. 401 Y 402 | 12d | 2015-06-22 | 2015-07-07 | 99, 76, 84, 92, 77 | 2015-06-16 | 2015-06-30 | 12d | 2d | 0d | CALENDARIO DE TRABAJO MONTERESERVA | 0% | 0% | 0% | 0% |
| 101 | 1.3.4.5 | MAMPOSTERIA INTERNA. 501 Y 502 | 12d | 2015-07-07 | 2015-07-22 | 100, 77, 85, 93, 78 | 2015-07-01 | 2015-07-14 | 12d | 2d | 0d | CALENDARIO DE TRABAJO MONTERESERVA | 0% | 0% | 0% | 0% |
| 102 | 1.3.4.6 | MAMPOSTERIA INTERNA. BAJILLO 601 Y 602 | 12d | 2015-07-22 | 2015-08-05 | 101, 78, 86, 94, 79 | 2015-07-15 | 2015-07-29 | 12d | 2d | 0d | CALENDARIO DE TRABAJO MONTERESERVA | 0% | 0% | 0% | 0% |
| 103 | 1.3.4.7 | MAMPOSTERIA INTERNA. ALTILLOS 601 Y 602 | 12d | 2015-08-05 | 2015-08-21 | 102, 79, 87, 95, 80 | 2015-07-30 | 2015-08-13 | 12d | 2d | 0d | CALENDARIO DE TRABAJO MONTERESERVA | 0% | 0% | 0% | 0% |

| ID | WBS | Task | Duration | Start | Finish | Predecessors | Baseline start | Baseline finish | Baseline duration | Total slack | Free slack | Calendar | Text1 | Text2 | Text5 | Text6 |
| --- | --- | --- | --- | --- | --- | --- | --- | --- | --- | --- | --- | --- | --- | --- | --- | --- |
| 104 | 1.3.5 | **ANCLAJES MAMPOSTERIA INTERNA Y DE FACHADA** | 64.52d | 2015-05-30 | 2015-08-28 |  | 2015-05-25 | 2015-08-21 | 65d | 14.52d |  | DIAS CALENDARIO 2 | 0% | 0% | 0% | 0% |
| 105 | 1.3.5.1 | ANCLAJES MAMPOSTERIA.SOTANO Y APARTAMENTOS 101 Y 102 | 6d | 2015-05-30 | 2015-06-06 | 62, 97 | 2015-05-25 | 2015-05-30 | 6d | 15d | 4.52d | CALENDARIO DE TRABAJO MONTERESERVA | 0% | 0% | 0% | 0% |
| 106 | 1.3.5.2 | ANCLAJES MAMPOSTERIA.LOBBY Y APTOS 201 Y 202 | 6d | 2015-06-05 | 2015-06-13 | 63, 98 | 2015-05-30 | 2015-06-05 | 6d | 10d | 5.52d | CALENDARIO DE TRABAJO MONTERESERVA | 0% | 0% | 0% | 0% |
| 107 | 1.3.5.3 | ANCLAJES MAMPOSTERIA. 301 Y 302 | 6d | 2015-06-22 | 2015-06-30 | 106, 64, 99 | 2015-06-16 | 2015-06-22 | 6d | 19d | 5d | CALENDARIO DE TRABAJO MONTERESERVA | 0% | 0% | 0% | 0% |
| 108 | 1.3.5.4 | ANCLAJES MAMPOSTERIA. 401 Y 402 | 6d | 2015-07-07 | 2015-07-14 | 107, 65, 100 | 2015-07-01 | 2015-07-07 | 6d | 16d | 6d | CALENDARIO DE TRABAJO MONTERESERVA | 0% | 0% | 0% | 0% |
| 109 | 1.3.5.5 | ANCLAJES MAMPOSTERIA. 501 Y 502 | 6d | 2015-07-22 | 2015-07-29 | 108, 66, 101 | 2015-07-15 | 2015-07-22 | 6d | 13d | 5d | CALENDARIO DE TRABAJO MONTERESERVA | 0% | 0% | 0% | 0% |
| 110 | 1.3.5.6 | ANCLAJES MAMPOSTERIA. BAJILLO 601 Y 602 | 6d | 2015-08-05 | 2015-08-13 | 109, 67, 102 | 2015-07-30 | 2015-08-05 | 6d | 10d | 6d | CALENDARIO DE TRABAJO MONTERESERVA | 0% | 0% | 0% | 0% |
| 111 | 1.3.5.7 | ANCLAJES MAMPOSTERIA ALTILLOS 601 Y 602 | 6d | 2015-08-21 | 2015-08-28 | 110, 68, 103 | 2015-08-14 | 2015-08-21 | 6d | 129d |  | CALENDARIO DE TRABAJO MONTERESERVA | 0% | 0% | 0% | 0% |
| 112 | 1.3.6 | **TRABAJOS CHIMENEA** | 38d | 2015-06-22 | 2015-08-13 |  | 2015-06-16 | 2015-08-05 | 37d | 132d |  | DIAS CALENDARIO 2 | 0% | 0% | 0% | 0% |
| 113 | 1.3.6.1 | TRABAJOS CHIMENEA. 301 Y 302 | 4d | 2015-06-22 | 2015-06-26 | 99 | 2015-06-16 | 2015-06-19 | 4d | 179d |  | CALENDARIO DE TRABAJO MONTERESERVA | 0% | 0% | 0% | 0% |
| 114 | 1.3.6.2 | TRABAJOS CHIMENEA. 401 Y 402 | 4d | 2015-07-07 | 2015-07-11 | 100 | 2015-07-01 | 2015-07-04 | 4d | 167d |  | CALENDARIO DE TRABAJO MONTERESERVA | 0% | 0% | 0% | 0% |
| 115 | 1.3.6.3 | TRABAJOS CHIMENEA. 501 Y 502 | 4d | 2015-07-22 | 2015-07-27 | 101 | 2015-07-15 | 2015-07-18 | 4d | 155d |  | CALENDARIO DE TRABAJO MONTERESERVA | 0% | 0% | 0% | 0% |
| 116 | 1.3.6.4 | TRABAJOS CHIMENEA 601 Y 602 | 6d | 2015-08-05 | 2015-08-13 | 102 | 2015-07-30 | 2015-08-05 | 6d | 141d |  | CALENDARIO DE TRABAJO MONTERESERVA | 0% | 0% | 0% | 0% |
| 117 | 1.3.7 | **PRUEBAS HIDRAULICAS** | 60.52d | 2015-05-30 | 2015-08-24 |  | 2015-05-25 | 2015-08-15 | 60d | 2d |  | DIAS CALENDARIO 2 | 0% | 0% | 0% | 0% |
| 118 | 1.3.7.1 | PRUEBAS HIDRAULICAS. SOTANO Y APARTAMENTOS 101 Y 102 | 2d | 2015-05-30 | 2015-06-02 | 97 | 2015-05-25 | 2015-05-26 | 2d | 19d | 8d | CALENDARIO DE TRABAJO MONTERESERVA | 0% | 0% | 0% | 0% |
| 119 | 1.3.7.2 | PRUEBAS HIDRAULICAS LOBBY Y APTOS 201 Y 202 | 2d | 2015-06-05 | 2015-06-09 | 98 | 2015-05-30 | 2015-06-01 | 2d | 14d | 9d | CALENDARIO DE TRABAJO MONTERESERVA | 0% | 0% | 0% | 0% |
| 120 | 1.3.7.3 | PRUEBAS HIDRAULICAS. 301 Y 302 | 2d | 2015-06-22 | 2015-06-24 | 119, 99 | 2015-06-16 | 2015-06-17 | 2d | 14d | 9d | CALENDARIO DE TRABAJO MONTERESERVA | 0% | 0% | 0% | 0% |
| 121 | 1.3.7.4 | PRUEBAS HIDRAULICAS.401 Y 402 | 2d | 2015-07-07 | 2015-07-09 | 120, 100 | 2015-07-01 | 2015-07-02 | 2d | 11d | 9d | CALENDARIO DE TRABAJO MONTERESERVA | 0% | 0% | 0% | 0% |
| 122 | 1.3.7.5 | PRUEBAS HIDRAULICAS. 501 Y 502 | 2d | 2015-07-22 | 2015-07-24 | 121, 101 | 2015-07-15 | 2015-07-16 | 2d | 8d | 5.48d | CALENDARIO DE TRABAJO MONTERESERVA | 0% | 0% | 0% | 0% |
| 123 | 1.3.7.6 | PRUEBAS HIDRAULICAS. 601 Y 602 BAJILLOS | 2d | 2015-08-05 | 2015-08-08 | 122, 102 | 2015-07-30 | 2015-07-31 | 2d | 5d | 3.52d | CALENDARIO DE TRABAJO MONTERESERVA | 0% | 0% | 0% | 0% |
| 124 | 1.3.7.7 | PRUEBAS HIDRAULICAS. 601 Y 602 ALTILLO | 2d | 2015-08-21 | 2015-08-24 | 123, 103 | 2015-08-14 | 2015-08-15 | 2d | 2d | 1d | CALENDARIO DE TRABAJO MONTERESERVA | 0% | 0% | 0% | 0% |
| 125 | 1.3.8 | **MAMPOSTERIA DE FACHADA** | 71.52d | 2015-05-30 | 2015-09-08 |  | 2015-05-25 | 2015-09-01 | 72d | 8.52d |  | DIAS CALENDARIO 2 | 0% | 0% | 0% | 0% |
| 126 | 1.3.8.1 | MAMPOSTERIA DE FACHADA ZONAS NO HABITABLES BAJO SOTANO | 12d | 2015-05-30 | 2015-06-16 | 127SF, 66 | 2015-05-25 | 2015-06-06 | 12d | 188d |  | CALENDARIO DE TRABAJO MONTERESERVA |  |  | 0% | 0% |
| 127 | 1.3.8.2 | MAMPOSTERIA DE FACHADA. SOTANO Y APTOS. 101 Y 102 | 10d | 2015-06-11 | 2015-06-24 | 89, 97, 67 | 2015-06-04 | 2015-06-17 | 10d | 0d |  | CALENDARIO DE TRABAJO MONTERESERVA | 0% | 0% | 0% | 0% |
| 128 | 1.3.8.3 | MAMPOSTERIA DE FACHADA. LOBBY Y APTOS. 201 Y 202 | 10d | 2015-06-24 | 2015-07-07 | 90, 98, 127, 68 | 2015-06-18 | 2015-06-30 | 10d | 0d |  | CALENDARIO DE TRABAJO MONTERESERVA | 0% | 0% | 0% | 0% |
| 129 | 1.3.8.4 | MAMPOSTERIA DE FACHADA. 301 Y 302 | 9d | 2015-07-07 | 2015-07-17 | 128, 91 | 2015-07-01 | 2015-07-10 | 9d | 0d |  | CALENDARIO DE TRABAJO MONTERESERVA | 0% | 0% | 0% | 0% |
| 130 | 1.3.8.5 | MAMPOSTERIA DE FACHADA. 401 Y 402 | 9d | 2015-07-17 | 2015-07-29 | 129, 92 | 2015-07-11 | 2015-07-22 | 9d | 0d |  | CALENDARIO DE TRABAJO MONTERESERVA | 0% | 0% | 0% | 0% |
| 131 | 1.3.8.6 | MAMPOSTERIA DE FACHADA. 501 Y 502 | 9d | 2015-07-29 | 2015-08-10 | 130, 93 | 2015-07-23 | 2015-08-01 | 9d | 0d |  | CALENDARIO DE TRABAJO MONTERESERVA | 0% | 0% | 0% | 0% |
| 132 | 1.3.8.7 | MAMPOSTERIA DE FACHADA. BAJILLOS 601 Y 602 | 9d | 2015-08-10 | 2015-08-21 | 131, 94 | 2015-08-03 | 2015-08-13 | 9d | 0d |  | CALENDARIO DE TRABAJO MONTERESERVA | 0% | 0% | 0% | 0% |
| 133 | 1.3.8.8 | MAMPOSTERIA DE FACHADA. ALTILLOS 601 Y 602 | 8d | 2015-08-21 | 2015-08-31 | 132, 95FF | 2015-08-14 | 2015-08-24 | 8d | 0d |  | CALENDARIO DE TRABAJO MONTERESERVA | 0% | 0% | 0% | 0% |
| 134 | 1.3.8.9 | MAMPOSTERIA DE FACHADA, ANTEPECHOS REMATE CUBIERTA. | 8d | 2015-08-29 | 2015-09-08 | 133FS-1d, 57FF+42d | 2015-08-24 | 2015-09-01 | 8d | 0d |  | CALENDARIO DE TRABAJO MONTERESERVA | 0% | 0% | 0% | 0% |

| ID | WBS | Task | Duration | Start | Finish | Predecessors | Baseline start | Baseline finish | Baseline duration | Total slack | Free slack | Calendar | Text5 | Text6 | Text1 | Text2 |
| --- | --- | --- | --- | --- | --- | --- | --- | --- | --- | --- | --- | --- | --- | --- | --- | --- |
| 135 | 1.3.9 | **MARCOS EN PIEDRA FACHADA** | 55d | 2015-06-24 | 2015-09-09 |  | 2015-06-18 | 2015-09-02 | 55d | 0d |  | DIAS CALENDARIO 2 | 0% | 0% |  |  |
| 136 | 1.3.9.1 | MARCOS EN PIEDRA FACHADA APTOS. 101 Y 102 | 8d | 2015-06-24 | 2015-07-04 | 127, 97, 144SS+4d | 2015-06-18 | 2015-06-26 | 8d | 6d | 1.52d | CALENDARIO DE TRABAJO MONTERESERVA | 0% | 0% |  |  |
| 137 | 1.3.9.2 | MARCOS EN PIEDRA FACHADA APTOS. 201 Y 202 | 8d | 2015-07-07 | 2015-07-16 | 128, 136, 98, 145SS+4d | 2015-07-01 | 2015-07-09 | 8d | 4d | 1d | CALENDARIO DE TRABAJO MONTERESERVA | 0% | 0% |  |  |
| 138 | 1.3.9.3 | MARCOS EN PIEDRA FACHADA APTOS. 301 Y 302 | 8d | 2015-07-17 | 2015-07-28 | 129, 137, 99, 146SS+4d | 2015-07-11 | 2015-07-21 | 8d | 3d | 0d | CALENDARIO DE TRABAJO MONTERESERVA | 0% | 0% |  |  |
| 139 | 1.3.9.4 | MARCOS EN PIEDRA FACHADA APTOS. 401 Y 402 | 8d | 2015-07-29 | 2015-08-08 | 130, 138, 100, 147SS+4d | 2015-07-23 | 2015-07-31 | 8d | 2d | 0.52d | CALENDARIO DE TRABAJO MONTERESERVA | 0% | 0% |  |  |
| 140 | 1.3.9.5 | MARCOS EN PIEDRA FACHADA APTOS. 501 Y 502 | 8d | 2015-08-10 | 2015-08-20 | 131, 139, 101, 148SS+4d | 2015-08-03 | 2015-08-12 | 8d | 1d |  | CALENDARIO DE TRABAJO MONTERESERVA | 0% | 0% |  |  |
| 141 | 1.3.9.6 | MARCOS EN PIEDRA FACHADA APTOS. 601 Y 602 BAJILLOS | 8d | 2015-08-21 | 2015-08-31 | 132, 140, 102, 149SS+4d | 2015-08-14 | 2015-08-24 | 8d | 0d |  | CALENDARIO DE TRABAJO MONTERESERVA | 0% | 0% |  |  |
| 142 | 1.3.9.7 | MARCOS EN PIEDRA FACHADA APTOS. 601 Y 602 ALTILLOS | 8d | 2015-08-31 | 2015-09-09 | 133, 141, 103, 150SS+4d | 2015-08-25 | 2015-09-02 | 8d | 0d |  | CALENDARIO DE TRABAJO MONTERESERVA | 0% | 0% |  |  |
| 143 | 1.3.10 | **PAÑETES INTERNOS** | 60d | 2015-06-12 | 2015-09-04 |  | 2015-06-05 | 2015-08-28 | 61d | 0.48d |  | DIAS CALENDARIO 2 | 0% | 0% | 0% | 0% |
| 144 | 1.3.10.1 | PAÑETES SOTANO Y APTOS. 101 Y 102 | 12d | 2015-06-12 | 2015-06-27 | 127FF+3d, 105, 118, 97 | 2015-06-05 | 2015-06-20 | 12d | 11d | 0d | CALENDARIO DE TRABAJO MONTERESERVA | 0% | 0% |  |  |
| 145 | 1.3.10.2 | PAÑETES LOBBY Y APTOS. 201 Y 202 | 12d | 2015-06-25 | 2015-07-10 | 119, 128FF+3d, 106, 98 | 2015-06-19 | 2015-07-03 | 12d | 1d | 0d | CALENDARIO DE TRABAJO MONTERESERVA | 0% | 0% | 0% | 0% |
| 146 | 1.3.10.3 | PAÑETES. 301 Y 302 | 9d | 2015-07-10 | 2015-07-22 | 145, 120, 129FF+3d, 106, 99 | 2015-07-04 | 2015-07-14 | 9d | 1d | 0d | CALENDARIO DE TRABAJO MONTERESERVA | 0% | 0% | 0% | 0% |
| 147 | 1.3.10.4 | PAÑETES. 401 Y 402 | 9d | 2015-07-22 | 2015-08-01 | 146, 121, 130FF+3d, 107, 100 | 2015-07-15 | 2015-07-25 | 9d | 1d | 0d | CALENDARIO DE TRABAJO MONTERESERVA | 0% | 0% | 0% | 0% |
| 148 | 1.3.10.5 | PAÑETES. 501 Y 502 | 9d | 2015-08-01 | 2015-08-13 | 147, 122, 131FF+3d, 108, 101 | 2015-07-27 | 2015-08-05 | 9d | 1d | 0d | CALENDARIO DE TRABAJO MONTERESERVA | 0% | 0% | 0% | 0% |
| 149 | 1.3.10.6 | PAÑETES. BAJILLOS 601 Y 602 | 9d | 2015-08-13 | 2015-08-25 | 148, 123, 132FF+3d, 109, 102 | 2015-08-06 | 2015-08-18 | 9d | 1d | 0d | CALENDARIO DE TRABAJO MONTERESERVA | 0% | 0% | 0% | 0% |
| 150 | 1.3.10.7 | PAÑETES. ALTILLOS 601 Y 602 | 9d | 2015-08-25 | 2015-09-04 | 149, 124, 133FF+3d, 110, 103 | 2015-08-19 | 2015-08-28 | 9d | 1d | 0d | CALENDARIO DE TRABAJO MONTERESERVA | 0% | 0% | 0% | 0% |
| 151 | 1.3.11 | **AFINADOS INTERNOS** | 54.52d | 2015-06-27 | 2015-09-11 |  | 2015-06-22 | 2015-09-04 | 55d | 51.52d |  | DIAS CALENDARIO 2 | 0% | 0% | 0% | 0% |
| 152 | 1.3.11.1 | AFINADOS SOTANO Y APTOS. 101 Y 102 | 6d | 2015-06-27 | 2015-07-06 | 144, 118 | 2015-06-22 | 2015-06-27 | 6d | 58d | 49.48d | CALENDARIO DE TRABAJO MONTERESERVA | 0% | 0% |  |  |
| 153 | 1.3.11.2 | AFINADOS LOBBY Y APTOS. 201 Y 202 | 6d | 2015-07-10 | 2015-07-17 | 145, 119 | 2015-07-04 | 2015-07-10 | 6d | 90d | 3d | CALENDARIO DE TRABAJO MONTERESERVA | 0% | 0% | 0% | 0% |
| 154 | 1.3.11.3 | AFINADOS. 301 Y 302 | 6d | 2015-07-22 | 2015-07-29 | 153, 146, 120 | 2015-07-15 | 2015-07-22 | 6d | 87d | 2.48d | CALENDARIO DE TRABAJO MONTERESERVA | 0% | 0% | 0% | 0% |
| 155 | 1.3.11.4 | AFINADOS. 401 Y 402 | 6d | 2015-08-01 | 2015-08-10 | 154, 147, 121 | 2015-07-27 | 2015-08-01 | 6d | 84d | 3d | CALENDARIO DE TRABAJO MONTERESERVA | 0% | 0% | 0% | 0% |
| 156 | 1.3.11.5 | AFINADOS. 501 Y 502 | 6d | 2015-08-13 | 2015-08-21 | 155, 148, 122 | 2015-08-06 | 2015-08-13 | 6d | 81d | 2d | CALENDARIO DE TRABAJO MONTERESERVA | 0% | 0% | 0% | 0% |
| 157 | 1.3.11.6 | AFINADOS. BAJILLOS 601 Y 602 | 6d | 2015-08-25 | 2015-09-01 | 156, 149, 123 | 2015-08-19 | 2015-08-25 | 6d | 78d | 3d | CALENDARIO DE TRABAJO MONTERESERVA | 0% | 0% | 0% | 0% |
| 158 | 1.3.11.7 | AFINADOS. ALTILLOS 601 Y 602 | 6d | 2015-09-04 | 2015-09-11 | 157, 150, 124 | 2015-08-29 | 2015-09-04 | 6d | 75d | 48d | CALENDARIO DE TRABAJO MONTERESERVA | 0% | 0% | 0% | 0% |

| ID | WBS | Task | Duration | Start | Finish | Predecessors | Baseline start | Baseline finish | Baseline duration | Total slack | Free slack | Calendar | Text1 | Text2 | Text5 | Text6 |
| --- | --- | --- | --- | --- | --- | --- | --- | --- | --- | --- | --- | --- | --- | --- | --- | --- |
| 159 | 1.3.12 | **TERRAZAS ( AFINADO, IMPERMEABILIACION,AFINADO, ACABADO,)** | 52d | 2015-07-22 | 2015-10-02 |  | 2015-07-15 | 2015-09-25 | 53d | 40.48d |  | DIAS CALENDARIO 2 | 0% | 0% | 0% | 0% |
| 160 | 1.3.12.1 | TERRAZAS LOBBY | 18d | 2015-07-22 | 2015-08-13 | 146 | 2015-07-15 | 2015-08-05 | 18d | 81d | 0d | CALENDARIO DE TRABAJO MONTERESERVA | 0% | 0% | 0% | 0% |
| 161 | 1.3.12.2 | TERRAZAS. P2 | 18d | 2015-08-01 | 2015-08-25 | 147 | 2015-07-27 | 2015-08-18 | 18d | 71d | 0d | CALENDARIO DE TRABAJO MONTERESERVA | 0% | 0% | 0% | 0% |
| 162 | 1.3.12.3 | TERRAZAS. P3 | 18d | 2015-08-13 | 2015-09-04 | 148 | 2015-08-06 | 2015-08-28 | 18d | 64d | 0d | CALENDARIO DE TRABAJO MONTERESERVA | 0% | 0% | 0% | 0% |
| 163 | 1.3.12.4 | TERRAZAS. P4 | 18d | 2015-08-25 | 2015-09-15 | 149 | 2015-08-19 | 2015-09-08 | 18d | 57d | 0d | CALENDARIO DE TRABAJO MONTERESERVA | 0% | 0% | 0% | 0% |
| 164 | 1.3.12.5 | TERRAZAS. P5 | 18d | 2015-09-04 | 2015-09-25 | 150 | 2015-08-29 | 2015-09-18 | 18d | 50d | 0d | CALENDARIO DE TRABAJO MONTERESERVA | 0% | 0% | 0% | 0% |
| 165 | 1.3.12.6 | TERRAZAS. P6 | 24d | 2015-09-04 | 2015-10-02 | 150 | 2015-08-29 | 2015-09-25 | 24d | 46d | 0d | CALENDARIO DE TRABAJO MONTERESERVA | 0% | 0% | 0% | 0% |
| 166 | 1.3.13 | **CIELOS DRY WALL TERRAZAS** | 46.48d | 2015-08-13 | 2015-10-17 |  | 2015-08-06 | 2015-10-09 | 47d | 71d |  | DIAS CALENDARIO 2 | 0% | 0% | 0% | 0% |
| 167 | 1.3.13.1 | CIELOS DRY WALL TERRAZAS LOBBY | 12d | 2015-08-13 | 2015-08-28 | 160 | 2015-08-06 | 2015-08-21 | 12d | 81d | 44d | CALENDARIO DE TRABAJO MONTERESERVA | 0% | 0% | 0% | 0% |
| 168 | 1.3.13.2 | CIELOS DRY WALL TERRAZAS. P2 | 12d | 2015-08-25 | 2015-09-08 | 161 | 2015-08-19 | 2015-09-01 | 12d | 78d | 43d | CALENDARIO DE TRABAJO MONTERESERVA | 0% | 0% | 0% | 0% |
| 169 | 1.3.13.3 | CIELOS DRY WALL TERRAZAS. P3 | 12d | 2015-09-04 | 2015-09-18 | 162 | 2015-08-29 | 2015-09-11 | 12d | 75d | 40d | CALENDARIO DE TRABAJO MONTERESERVA | 0% | 0% | 0% | 0% |
| 170 | 1.3.13.4 | CIELOS DRY WALL TERRAZAS. P4 | 12d | 2015-09-15 | 2015-09-29 | 163 | 2015-09-09 | 2015-09-22 | 12d | 71d | 38d | CALENDARIO DE TRABAJO MONTERESERVA | 0% | 0% | 0% | 0% |
| 171 | 1.3.13.5 | CIELOS DRY WALL TERRAZAS. P5 | 12d | 2015-09-25 | 2015-10-09 | 164 | 2015-09-19 | 2015-10-02 | 12d | 67d | 34d | CALENDARIO DE TRABAJO MONTERESERVA | 0% | 0% | 0% | 0% |
| 172 | 1.3.13.6 | CIELOS DRY WALL TERRAZAS. P5 | 12d | 2015-10-02 | 2015-10-17 | 165 | 2015-09-26 | 2015-10-09 | 12d | 87d |  | CALENDARIO DE TRABAJO MONTERESERVA | 0% | 0% | 0% | 0% |
| 173 | 1.3.14 | **TRATAMIENTO DE FACHADA** | 25d | 2015-09-02 | 2015-10-07 |  | 2015-08-27 | 2015-09-30 | 25d | 0d |  | DIAS CALENDARIO 2 | 0% | 0% | 0% | 0% |
| 174 | 1.3.14.1 | LAVADO DE FACHADA | 24d | 2015-09-02 | 2015-09-30 | 142FF+18d, 133 | 2015-08-27 | 2015-09-23 | 24d | 0d |  | CALENDARIO DE TRABAJO MONTERESERVA | 0% | 0% | 0% | 0% |
| 175 | 1.3.14.2 | IMPERMEABILIZACION FACHADA | 6d | 2015-09-30 | 2015-10-07 | 174 | 2015-09-24 | 2015-09-30 | 6d | 29d | 0d | CALENDARIO DE TRABAJO MONTERESERVA | 0% | 0% | 0% | 0% |
| 176 | 1.3.15 | **BARANDAS EN VIDRIO Y ACERO TERRAZAS** | 40d | 2015-10-07 | 2015-12-02 |  | 2015-10-01 | 2015-11-25 | 40d | 26d |  | DIAS CALENDARIO 2 | 0% | 0% | 0% | 0% |
| 177 | 1.3.15.1 | BARANDAS EN VIDRIO Y ACERO TERRAZAS SOTANO | 12d | 2015-10-07 | 2015-10-22 | 175 | 2015-10-01 | 2015-10-15 | 12d | 29d | 0d | CALENDARIO DE TRABAJO MONTERESERVA | 0% | 0% | 0% | 0% |
| 178 | 1.3.15.2 | BARANDAS EN VIDRIO Y ACERO TERRAZAS LOBBY | 6d | 2015-10-22 | 2015-10-29 | 177 | 2015-10-16 | 2015-10-22 | 6d | 29d | 0d | CALENDARIO DE TRABAJO MONTERESERVA | 0% | 0% | 0% | 0% |
| 179 | 1.3.15.3 | BARANDAS EN VIDRIO Y ACERO TERRAZAS P2 | 6d | 2015-10-29 | 2015-11-06 | 178, 160, 167 | 2015-10-23 | 2015-10-29 | 6d | 29d | 0d | CALENDARIO DE TRABAJO MONTERESERVA | 0% | 0% | 0% | 0% |
| 180 | 1.3.15.4 | BARANDAS EN VIDRIO Y ACERO TERRAZAS. P3 | 6d | 2015-11-06 | 2015-11-13 | 179, 161, 168 | 2015-10-30 | 2015-11-06 | 6d | 29d | 0d | CALENDARIO DE TRABAJO MONTERESERVA | 0% | 0% | 0% | 0% |
| 181 | 1.3.15.5 | BARANDAS EN VIDRIO Y ACERO TERRAZAS P4 | 5d | 2015-11-13 | 2015-11-20 | 180, 162, 169 | 2015-11-07 | 2015-11-12 | 5d | 29d | 0d | CALENDARIO DE TRABAJO MONTERESERVA | 0% | 0% | 0% | 0% |
| 182 | 1.3.15.6 | BARANDAS EN VIDRIO Y ACERO TERRAZAS P5 | 5d | 2015-11-20 | 2015-11-26 | 181, 163, 170 | 2015-11-13 | 2015-11-19 | 5d | 29d | 0d | CALENDARIO DE TRABAJO MONTERESERVA | 0% | 0% | 0% | 0% |
| 183 | 1.3.15.7 | BARANDAS EN VIDRIO Y ACERO TERRAZAS P6 | 5d | 2015-11-26 | 2015-12-02 | 182, 164, 171 | 2015-11-20 | 2015-11-25 | 5d | 29d |  | CALENDARIO DE TRABAJO MONTERESERVA | 0% | 0% | 0% | 0% |

| ID | WBS | Task | Duration | Start | Finish | Predecessors | Baseline start | Baseline finish | Baseline duration | Total slack | Free slack | Calendar | Text1 | Text2 | Text5 | Text6 |
| --- | --- | --- | --- | --- | --- | --- | --- | --- | --- | --- | --- | --- | --- | --- | --- | --- |
| 184 | 1.3.16 | **VENTANERIA** | 82d | 2015-07-28 | 2015-11-19 |  | 2015-07-22 | 2015-11-11 | 81d | 3d |  | DIAS CALENDARIO 2 | 0% | 0% | 0% | 0% |
| 185 | 1.3.16.1 | ACTA DE VANOS | 8d | 2015-07-28 | 2015-08-06 | 138 | 2015-07-22 | 2015-07-30 | 8d | 3d |  | CALENDARIO DE TRABAJO MONTERESERVA | 0% | 0% | 0% | 0% |
| 186 | 1.3.16.2 | VENTANERIA SOTANO APTOS. 101 Y 102 | 5d | 2015-09-30 | 2015-10-06 | 185FS+42d, 174 | 2015-09-24 | 2015-09-29 | 5d | 0d |  | CALENDARIO DE TRABAJO MONTERESERVA | 0% | 0% | 0% | 0% |
| 187 | 1.3.16.3 | VENTANERIA. LOBBY APTOS 201 Y 202 | 5d | 2015-10-06 | 2015-10-13 | 186 | 2015-09-30 | 2015-10-05 | 5d | 5d | 0d | CALENDARIO DE TRABAJO MONTERESERVA | 0% | 0% | 0% | 0% |
| 188 | 1.3.16.4 | VENTANERIA APTOS. 301 Y 302 | 6d | 2015-10-13 | 2015-10-20 | 185FS+42d, 174, 187 | 2015-10-06 | 2015-10-13 | 6d | 7d | 0d | CALENDARIO DE TRABAJO MONTERESERVA | 0% | 0% | 0% | 0% |
| 189 | 1.3.16.5 | VENTANERIA APTOS 401 Y 402 | 6d | 2015-10-20 | 2015-10-27 | 188 | 2015-10-14 | 2015-10-20 | 6d | 9d | 0d | CALENDARIO DE TRABAJO MONTERESERVA | 0% | 0% | 0% | 0% |
| 190 | 1.3.16.6 | VENTANERIA APTOS 501 Y 502 | 6d | 2015-10-27 | 2015-11-04 | 189 | 2015-10-21 | 2015-10-27 | 6d | 11d | 0d | CALENDARIO DE TRABAJO MONTERESERVA | 0% | 0% | 0% | 0% |
| 191 | 1.3.16.7 | VENTANERIA APTOS 601 Y 602 BAJILLOS | 6d | 2015-11-04 | 2015-11-11 | 190 | 2015-10-28 | 2015-11-04 | 6d | 13d | 0d | CALENDARIO DE TRABAJO MONTERESERVA | 0% | 0% | 0% | 0% |
| 192 | 1.3.16.8 | VENTANERIA APTOS 601 Y 602 ALTILLOS | 6d | 2015-11-11 | 2015-11-19 | 191 | 2015-11-05 | 2015-11-11 | 6d | 14d | 0d | CALENDARIO DE TRABAJO MONTERESERVA | 0% | 0% | 0% | 0% |
| 193 | 1.3.17 | **TRABAJOS DE CUBIERTA** | 29d | 2015-09-08 | 2015-10-19 |  | 2015-09-02 | 2015-10-10 | 28d | 0d |  | DIAS CALENDARIO 2 | 0% | 0% | 0% | 0% |
| 194 | 1.3.17.1 | CARGUE Y PENDIENTADO DE PISO | 6d | 2015-09-08 | 2015-09-15 | 134 | 2015-09-02 | 2015-09-08 | 6d | 0d |  | CALENDARIO DE TRABAJO MONTERESERVA | 0% | 0% | 0% | 0% |
| 195 | 1.3.17.2 | IMPERMEABILIZACION | 6d | 2015-09-15 | 2015-09-22 | 194 | 2015-09-09 | 2015-09-15 | 6d | 86d | 0d | CALENDARIO DE TRABAJO MONTERESERVA | 0% | 0% | 0% | 0% |
| 196 | 1.3.17.3 | AFINADO DE PISO 2 | 6d | 2015-09-22 | 2015-09-29 | 195 | 2015-09-16 | 2015-09-22 | 6d | 86d | 0d | CALENDARIO DE TRABAJO MONTERESERVA | 0% | 0% | 0% | 0% |
| 197 | 1.3.17.4 | ACABADO FINAL | 18d | 2015-09-26 | 2015-10-19 | 196FS-2d | 2015-09-21 | 2015-10-10 | 18d | 86d |  | CALENDARIO DE TRABAJO MONTERESERVA | 0% | 0% | 0% | 0% |
| 198 | 1.3.18 | **CAJAS ELECTRICAS Y CABLEADO ELECTRICO** | 36d | 2015-10-06 | 2015-11-25 |  | 2015-09-30 | 2015-11-18 | 36d | 58d |  | DIAS CALENDARIO 2 | 0% | 0% | 0% | 0% |
| 199 | 1.3.18.1 | CAJAS ELECTRICAS Y CABLEADO ELECTRICO. APTOS. 101 Y 102 | 5d | 2015-10-06 | 2015-10-13 | 186 | 2015-09-30 | 2015-10-05 | 5d | 91d |  | CALENDARIO DE TRABAJO MONTERESERVA | 0% | 0% | 0% | 0% |
| 200 | 1.3.18.2 | CAJAS ELECTRICAS Y CABLEADO ELECTRICO. LOBBY APTOS. 201 Y 202 | 5d | 2015-10-13 | 2015-10-19 | 187 | 2015-10-06 | 2015-10-10 | 5d | 86d |  | CALENDARIO DE TRABAJO MONTERESERVA | 0% | 0% | 0% | 0% |
| 201 | 1.3.18.3 | CAJAS ELECTRICAS Y CABLEADO ELECTRICO APTOS. 301 Y 302 | 5d | 2015-10-20 | 2015-10-26 | 188 | 2015-10-14 | 2015-10-19 | 5d | 80d |  | CALENDARIO DE TRABAJO MONTERESERVA | 0% | 0% | 0% | 0% |
| 202 | 1.3.18.4 | CAJAS ELECTRICAS Y CABLEADO ELECTRICO 401 Y 402 | 5d | 2015-10-27 | 2015-11-03 | 189 | 2015-10-21 | 2015-10-26 | 5d | 74d |  | CALENDARIO DE TRABAJO MONTERESERVA | 0% | 0% | 0% | 0% |
| 203 | 1.3.18.5 | CAJAS ELECTRICAS Y CABLEADO ELECTRICO 501 Y 502 | 5d | 2015-11-04 | 2015-11-10 | 190 | 2015-10-28 | 2015-11-03 | 5d | 68d |  | CALENDARIO DE TRABAJO MONTERESERVA | 0% | 0% | 0% | 0% |
| 204 | 1.3.18.6 | CAJAS ELECTRICAS Y CABLEADO ELECTRICO 601 Y 602 BAJILLOS | 5d | 2015-11-11 | 2015-11-18 | 191 | 2015-11-05 | 2015-11-10 | 5d | 62d |  | CALENDARIO DE TRABAJO MONTERESERVA | 0% | 0% | 0% | 0% |
| 205 | 1.3.18.7 | CAJAS ELECTRICAS Y CABLEADO ELECTRICO 601 Y 602 ALTILLOS | 5d | 2015-11-19 | 2015-11-25 | 192 | 2015-11-12 | 2015-11-18 | 5d | 56d |  | CALENDARIO DE TRABAJO MONTERESERVA | 0% | 0% | 0% | 0% |
| 206 | 1.4 | **TRABAJOS PUNTO FIJO** | 90.48d | 2015-09-18 | 2016-01-23 |  | 2015-09-12 | 2016-01-16 | 90d | 15.52d |  | DIAS CALENDARIO 2 | 0% | 0% | 0% | 0% |
| 207 | 1.4.1 | **PUNTO FIJO SOTANO** | 40.48d | 2015-09-25 | 2015-11-21 |  | 2015-09-19 | 2015-11-13 | 40d | 46d |  | DIAS CALENDARIO 2 | 0% | 0% | 0% | 0% |
| 208 | 1.4.1.1 | SHUT DE BASURAS | 4d | 2015-09-25 | 2015-09-30 | 224 | 2015-09-19 | 2015-09-23 | 4d | 53d | 0d | CALENDARIO DE TRABAJO MONTERESERVA | 0% | 0% | 0% | 0% |
| 209 | 1.4.1.2 | REMATES MAMPOSTERIA | 4d | 2015-09-30 | 2015-10-05 | 130, 208 | 2015-09-24 | 2015-09-28 | 4d | 53d | 0d | CALENDARIO DE TRABAJO MONTERESERVA | 0% | 0% | 0% | 0% |
| 210 | 1.4.1.3 | PROLONGACIONES ELECTRICAS | 1d | 2015-10-05 | 2015-10-06 | 209 | 2015-09-29 | 2015-09-29 | 1d | 53d | 0d | CALENDARIO DE TRABAJO MONTERESERVA | 0% | 0% | 0% | 0% |
| 211 | 1.4.1.4 | PAÑETES | 2d | 2015-10-06 | 2015-10-08 | 210 | 2015-09-30 | 2015-10-01 | 2d | 53d | 0d | CALENDARIO DE TRABAJO MONTERESERVA | 0% | 0% | 0% | 0% |
| 212 | 1.4.1.5 | ESTUCO Y PRIMERA MANO | 4d | 2015-10-08 | 2015-10-14 | 211 | 2015-10-02 | 2015-10-06 | 4d | 53d | 0d | CALENDARIO DE TRABAJO MONTERESERVA | 0% | 0% | 0% | 0% |
| 213 | 1.4.1.6 | AFINADO DE PISOS | 2d | 2015-10-14 | 2015-10-16 | 152, 212 | 2015-10-07 | 2015-10-08 | 2d | 53d | 0d | CALENDARIO DE TRABAJO MONTERESERVA | 0% | 0% | 0% | 0% |
| 214 | 1.4.1.7 | DETALLADO Y SEGUNDA MANO | 2d | 2015-10-16 | 2015-10-19 | 213 | 2015-10-09 | 2015-10-10 | 2d | 53d | 0d | CALENDARIO DE TRABAJO MONTERESERVA | 0% | 0% | 0% | 0% |
| 215 | 1.4.1.8 | INSTALACION TAPA SHUT | 2d | 2015-10-19 | 2015-10-21 | 208, 214 | 2015-10-13 | 2015-10-14 | 2d | 53d | 0d | CALENDARIO DE TRABAJO MONTERESERVA | 0% | 0% | 0% | 0% |
| 216 | 1.4.1.9 | INSTALACION DE PISOS | 12d | 2015-10-21 | 2015-11-05 | 215 | 2015-10-15 | 2015-10-28 | 12d | 53d | 0d | CALENDARIO DE TRABAJO MONTERESERVA | 0% | 0% | 0% | 0% |
| 217 | 1.4.1.10 | PASAMANOS | 2d | 2015-11-05 | 2015-11-07 | 216 | 2015-10-29 | 2015-10-30 | 2d | 53d | 0d | CALENDARIO DE TRABAJO MONTERESERVA | 0% | 0% | 0% | 0% |
| 218 | 1.4.1.11 | EQUIPOS CONTRAINCENDIO | 2d | 2015-11-07 | 2015-11-10 | 217 | 2015-10-31 | 2015-11-03 | 2d | 53d | 0d | CALENDARIO DE TRABAJO MONTERESERVA | 0% | 0% | 0% | 0% |
| 219 | 1.4.1.12 | PUERTAS ACCESO EN MADERA | 1d | 2015-11-10 | 2015-11-11 | 218 | 2015-11-04 | 2015-11-04 | 1d | 53d | 0d | CALENDARIO DE TRABAJO MONTERESERVA | 0% | 0% | 0% | 0% |
| 220 | 1.4.1.13 | DETALLADO Y TERCERA MANO DE PINTURA | 2d | 2015-11-11 | 2015-11-13 | 219 | 2015-11-05 | 2015-11-06 | 2d | 53d | 0d | CALENDARIO DE TRABAJO MONTERESERVA | 0% | 0% | 0% | 0% |
| 221 | 1.4.1.14 | ASEO PREENTREGA ( INCLUYE APTO) | 6d | 2015-11-13 | 2015-11-21 | 220 | 2015-11-07 | 2015-11-13 | 6d | 53d | 40d | CALENDARIO DE TRABAJO MONTERESERVA | 0% | 0% | 0% | 0% |

| ID | WBS | Task | Duration | Start | Finish | Predecessors | Baseline start | Baseline finish | Baseline duration | Total slack | Free slack | Calendar | Text1 | Text2 | Text5 | Text6 |
| --- | --- | --- | --- | --- | --- | --- | --- | --- | --- | --- | --- | --- | --- | --- | --- | --- |
| 222 | 1.4.2 | **PUNTO FIJO LOBBY** | 43d | 2015-09-18 | 2015-11-18 |  | 2015-09-12 | 2015-11-10 | 42d | 42d |  | DIAS CALENDARIO 2 | 0% | 0% | 0% | 0% |
| 223 | 1.4.2.1 | SHUT DE BASURAS | 4d | 2015-09-18 | 2015-09-23 | 224SF | 2015-09-12 | 2015-09-17 | 4d | 82d | 17.48d | CALENDARIO DE TRABAJO MONTERESERVA | 0% | 0% | 0% | 0% |
| 224 | 1.4.2.2 | REMATES MAMPOSTERIA | 2d | 2015-09-23 | 2015-09-25 | 160SF, 187SF-9d | 2015-09-17 | 2015-09-19 | 2d | 44d | 0d | CALENDARIO DE TRABAJO MONTERESERVA | 0% | 0% | 0% | 0% |
| 225 | 1.4.2.3 | PROLONGACIONES ELECTRICAS | 2d | 2015-09-25 | 2015-09-28 | 224 | 2015-09-19 | 2015-09-21 | 2d | 62d | 0d | CALENDARIO DE TRABAJO MONTERESERVA | 0% | 0% | 0% | 0% |
| 226 | 1.4.2.4 | PAÑETES | 2d | 2015-09-28 | 2015-09-30 | 225 | 2015-09-22 | 2015-09-23 | 2d | 62d | 0d | CALENDARIO DE TRABAJO MONTERESERVA | 0% | 0% | 0% | 0% |
| 227 | 1.4.2.5 | ESTUCO Y PRIMERA MANO | 4d | 2015-10-07 | 2015-10-13 | 226FS+6d | 2015-10-01 | 2015-10-05 | 4d | 62d | 0d | CALENDARIO DE TRABAJO MONTERESERVA | 0% | 0% | 0% | 0% |
| 228 | 1.4.2.6 | AFINADO DE PISOS | 2d | 2015-10-13 | 2015-10-15 | 227, 153 | 2015-10-06 | 2015-10-07 | 2d | 62d | 0d | CALENDARIO DE TRABAJO MONTERESERVA | 0% | 0% | 0% | 0% |
| 229 | 1.4.2.7 | DETALLADO Y SEGUNDA MANO | 2d | 2015-10-15 | 2015-10-17 | 228 | 2015-10-08 | 2015-10-09 | 2d | 62d | 0d | CALENDARIO DE TRABAJO MONTERESERVA | 0% | 0% | 0% | 0% |
| 230 | 1.4.2.8 | INSTALACION TAPA SHUT | 2d | 2015-10-17 | 2015-10-20 | 229, 223 | 2015-10-10 | 2015-10-13 | 2d | 62d | 0d | CALENDARIO DE TRABAJO MONTERESERVA | 0% | 0% | 0% | 0% |
| 231 | 1.4.2.9 | INSTALACION DE PISOS | 12d | 2015-10-17 | 2015-10-31 | 230SS | 2015-10-10 | 2015-10-24 | 12d | 62d | 0d | CALENDARIO DE TRABAJO MONTERESERVA | 0% | 0% | 0% | 0% |
| 232 | 1.4.2.10 | PASAMANOS | 2d | 2015-10-31 | 2015-11-04 | 231 | 2015-10-26 | 2015-10-27 | 2d | 62d | 0d | CALENDARIO DE TRABAJO MONTERESERVA | 0% | 0% | 0% | 0% |
| 233 | 1.4.2.11 | EQUIPOS CONTRAINCENDIO | 2d | 2015-11-04 | 2015-11-06 | 232 | 2015-10-28 | 2015-10-29 | 2d | 62d | 0d | CALENDARIO DE TRABAJO MONTERESERVA | 0% | 0% | 0% | 0% |
| 234 | 1.4.2.12 | PUERTAS ACCESO EN MADERA | 1d | 2015-11-06 | 2015-11-07 | 233 | 2015-10-30 | 2015-10-30 | 1d | 62d | 0d | CALENDARIO DE TRABAJO MONTERESERVA | 0% | 0% | 0% | 0% |
| 235 | 1.4.2.13 | DETALLADO Y TERCERA MANO DE PINTURA | 2d | 2015-11-07 | 2015-11-10 | 234 | 2015-10-31 | 2015-11-03 | 2d | 62d | 0d | CALENDARIO DE TRABAJO MONTERESERVA | 0% | 0% | 0% | 0% |
| 236 | 1.4.2.14 | ASEO PREENTREGA ( INCLUYE APTO) | 6d | 2015-11-10 | 2015-11-18 | 235 | 2015-11-04 | 2015-11-10 | 6d | 62d |  | CALENDARIO DE TRABAJO MONTERESERVA | 0% | 0% | 0% | 0% |
| 237 | 1.4.3 | **PUNTO FIJO P2** | 37.48d | 2015-10-07 | 2015-11-28 |  | 2015-10-01 | 2015-11-21 | 37d | 31d |  | DIAS CALENDARIO 2 | 0% | 0% | 0% | 0% |
| 238 | 1.4.3.1 | SHUT DE BASURAS | 4d | 2015-10-07 | 2015-10-13 | 239SF | 2015-10-01 | 2015-10-06 | 4d | 70d | 15d | CALENDARIO DE TRABAJO MONTERESERVA | 0% | 0% | 0% | 0% |
| 239 | 1.4.3.2 | REMATES MAMPOSTERIA | 2d | 2015-10-13 | 2015-10-15 | 224, 161, 188SS | 2015-10-06 | 2015-10-07 | 2d | 30d | 0d | CALENDARIO DE TRABAJO MONTERESERVA | 0% | 0% | 0% | 0% |
| 240 | 1.4.3.3 | PROLONGACIONES ELECTRICAS | 1d | 2015-10-15 | 2015-10-16 | 239 | 2015-10-08 | 2015-10-08 | 1d | 53d | 0d | CALENDARIO DE TRABAJO MONTERESERVA | 0% | 0% | 0% | 0% |
| 241 | 1.4.3.4 | PAÑETES | 2d | 2015-10-16 | 2015-10-19 | 240 | 2015-10-09 | 2015-10-10 | 2d | 53d | 0d | CALENDARIO DE TRABAJO MONTERESERVA | 0% | 0% | 0% | 0% |
| 242 | 1.4.3.5 | ESTUCO Y PRIMERA MANO | 2d | 2015-10-26 | 2015-10-28 | 241FS+6d | 2015-10-20 | 2015-10-21 | 2d | 53d | 0d | CALENDARIO DE TRABAJO MONTERESERVA | 0% | 0% | 0% | 0% |
| 243 | 1.4.3.6 | AFINADO DE PISOS | 2d | 2015-10-28 | 2015-10-30 | 242, 154 | 2015-10-22 | 2015-10-23 | 2d | 53d | 0d | CALENDARIO DE TRABAJO MONTERESERVA | 0% | 0% | 0% | 0% |
| 244 | 1.4.3.7 | DETALLADO Y SEGUNDA MANO | 2d | 2015-10-30 | 2015-11-03 | 243 | 2015-10-24 | 2015-10-26 | 2d | 53d | 0d | CALENDARIO DE TRABAJO MONTERESERVA | 0% | 0% | 0% | 0% |
| 245 | 1.4.3.8 | INSTALACION TAPA SHUT | 2d | 2015-11-03 | 2015-11-05 | 244, 238 | 2015-10-27 | 2015-10-28 | 2d | 53d | 0d | CALENDARIO DE TRABAJO MONTERESERVA | 0% | 0% | 0% | 0% |
| 246 | 1.4.3.9 | INSTALACION DE PISOS | 6d | 2015-11-05 | 2015-11-12 | 245 | 2015-10-29 | 2015-11-05 | 6d | 53d | 0d | CALENDARIO DE TRABAJO MONTERESERVA | 0% | 0% | 0% | 0% |
| 247 | 1.4.3.10 | PASAMANOS | 2d | 2015-11-12 | 2015-11-14 | 246 | 2015-11-06 | 2015-11-07 | 2d | 53d | 0d | CALENDARIO DE TRABAJO MONTERESERVA | 0% | 0% | 0% | 0% |
| 248 | 1.4.3.11 | EQUIPOS CONTRAINCENDIO | 2d | 2015-11-14 | 2015-11-18 | 247 | 2015-11-09 | 2015-11-10 | 2d | 53d | 0d | CALENDARIO DE TRABAJO MONTERESERVA | 0% | 0% | 0% | 0% |
| 249 | 1.4.3.12 | PUERTAS ACCESO EN MADERA | 1d | 2015-11-18 | 2015-11-19 | 248 | 2015-11-11 | 2015-11-11 | 1d | 53d | 0d | CALENDARIO DE TRABAJO MONTERESERVA | 0% | 0% | 0% | 0% |
| 250 | 1.4.3.13 | DETALLADO Y TERCERA MANO DE PINTURA | 2d | 2015-11-19 | 2015-11-21 | 249 | 2015-11-12 | 2015-11-13 | 2d | 53d | 0d | CALENDARIO DE TRABAJO MONTERESERVA | 0% | 0% | 0% | 0% |
| 251 | 1.4.3.14 | ASEO PREENTREGA ( INCLUYE APTO) | 6d | 2015-11-21 | 2015-11-28 | 250 | 2015-11-14 | 2015-11-21 | 6d | 53d |  | CALENDARIO DE TRABAJO MONTERESERVA | 0% | 0% | 0% | 0% |

| ID | WBS | Task | Duration | Start | Finish | Predecessors | Baseline start | Baseline finish | Baseline duration | Total slack | Free slack | Calendar | Text1 | Text2 | Text5 | Text6 |
| --- | --- | --- | --- | --- | --- | --- | --- | --- | --- | --- | --- | --- | --- | --- | --- | --- |
| 252 | 1.4.4 | **PUNTO FIJO P3** | 37d | 2015-10-14 | 2015-12-04 |  | 2015-10-07 | 2015-11-27 | 38d | 27.48d |  | DIAS CALENDARIO 2 | 0% | 0% | 0% | 0% |
| 253 | 1.4.4.1 | SHUT DE BASURAS | 4d | 2015-10-14 | 2015-10-19 | 254SF | 2015-10-07 | 2015-10-13 | 4d | 65d | 15d | CALENDARIO DE TRABAJO MONTERESERVA | 0% | 0% | 0% | 0% |
| 254 | 1.4.4.2 | REMATES MAMPOSTERIA | 2d | 2015-10-19 | 2015-10-21 | 239, 162, 189SS-1d | 2015-10-13 | 2015-10-14 | 2d | 27d | 0d | CALENDARIO DE TRABAJO MONTERESERVA | 0% | 0% | 0% | 0% |
| 255 | 1.4.4.3 | PROLONGACIONES ELECTRICAS | 1d | 2015-10-21 | 2015-10-22 | 254 | 2015-10-15 | 2015-10-15 | 1d | 48d | 0d | CALENDARIO DE TRABAJO MONTERESERVA | 0% | 0% | 0% | 0% |
| 256 | 1.4.4.4 | PAÑETES | 2d | 2015-10-22 | 2015-10-24 | 255 | 2015-10-16 | 2015-10-17 | 2d | 48d | 0d | CALENDARIO DE TRABAJO MONTERESERVA | 0% | 0% | 0% | 0% |
| 257 | 1.4.4.5 | ESTUCO Y PRIMERA MANO | 2d | 2015-10-31 | 2015-11-04 | 256FS+6d | 2015-10-26 | 2015-10-27 | 2d | 48d | 0d | CALENDARIO DE TRABAJO MONTERESERVA | 0% | 0% | 0% | 0% |
| 258 | 1.4.4.6 | AFINADO DE PISOS | 2d | 2015-11-04 | 2015-11-06 | 257, 155 | 2015-10-28 | 2015-10-29 | 2d | 48d | 0d | CALENDARIO DE TRABAJO MONTERESERVA | 0% | 0% | 0% | 0% |
| 259 | 1.4.4.7 | DETALLADO Y SEGUNDA MANO | 2d | 2015-11-06 | 2015-11-09 | 258 | 2015-10-30 | 2015-10-31 | 2d | 48d | 0d | CALENDARIO DE TRABAJO MONTERESERVA | 0% | 0% | 0% | 0% |
| 260 | 1.4.4.8 | INSTALACION TAPA SHUT | 2d | 2015-11-09 | 2015-11-11 | 259, 253 | 2015-11-03 | 2015-11-04 | 2d | 48d | 0d | CALENDARIO DE TRABAJO MONTERESERVA | 0% | 0% | 0% | 0% |
| 261 | 1.4.4.9 | INSTALACION DE PISOS | 6d | 2015-11-11 | 2015-11-19 | 260 | 2015-11-05 | 2015-11-11 | 6d | 48d | 0d | CALENDARIO DE TRABAJO MONTERESERVA | 0% | 0% | 0% | 0% |
| 262 | 1.4.4.10 | PASAMANOS | 2d | 2015-11-19 | 2015-11-21 | 261 | 2015-11-12 | 2015-11-13 | 2d | 48d | 0d | CALENDARIO DE TRABAJO MONTERESERVA | 0% | 0% | 0% | 0% |
| 263 | 1.4.4.11 | EQUIPOS CONTRAINCENDIO | 2d | 2015-11-21 | 2015-11-24 | 262 | 2015-11-14 | 2015-11-17 | 2d | 48d | 0d | CALENDARIO DE TRABAJO MONTERESERVA | 0% | 0% | 0% | 0% |
| 264 | 1.4.4.12 | PUERTAS ACCESO EN MADERA | 1d | 2015-11-24 | 2015-11-25 | 263 | 2015-11-18 | 2015-11-18 | 1d | 48d | 0d | CALENDARIO DE TRABAJO MONTERESERVA | 0% | 0% | 0% | 0% |
| 265 | 1.4.4.13 | DETALLADO Y TERCERA MANO DE PINTURA | 2d | 2015-11-25 | 2015-11-27 | 264 | 2015-11-19 | 2015-11-20 | 2d | 48d | 0d | CALENDARIO DE TRABAJO MONTERESERVA | 0% | 0% | 0% | 0% |
| 266 | 1.4.4.14 | ASEO PREENTREGA ( INCLUYE APTO) | 6d | 2015-11-27 | 2015-12-04 | 265 | 2015-11-21 | 2015-11-27 | 6d | 48d |  | CALENDARIO DE TRABAJO MONTERESERVA | 0% | 0% | 0% | 0% |
| 267 | 1.4.5 | **PUNTO FIJO P4** | 37.48d | 2015-10-21 | 2015-12-12 |  | 2015-10-15 | 2015-12-04 | 37d | 24d |  | DIAS CALENDARIO 2 | 0% | 0% | 0% | 0% |
| 268 | 1.4.5.1 | SHUT DE BAURAS | 4d | 2015-10-21 | 2015-10-26 | 269SF | 2015-10-15 | 2015-10-20 | 4d | 59d | 16d | CALENDARIO DE TRABAJO MONTERESERVA | 0% | 0% | 0% | 0% |
| 269 | 1.4.5.2 | REMATES MAMPOSTERIA | 2d | 2015-10-26 | 2015-10-28 | 254, 163, 190SS-1d | 2015-10-20 | 2015-10-21 | 2d | 23d | 0d | CALENDARIO DE TRABAJO MONTERESERVA | 0% | 0% | 0% | 0% |
| 270 | 1.4.5.3 | PROLONGACIONES ELECTRICAS | 1d | 2015-10-28 | 2015-10-29 | 269 | 2015-10-22 | 2015-10-22 | 1d | 42d | 0d | CALENDARIO DE TRABAJO MONTERESERVA | 0% | 0% | 0% | 0% |
| 271 | 1.4.5.4 | PAÑETES | 2d | 2015-10-29 | 2015-10-31 | 270 | 2015-10-23 | 2015-10-24 | 2d | 42d | 0d | CALENDARIO DE TRABAJO MONTERESERVA | 0% | 0% | 0% | 0% |
| 272 | 1.4.5.5 | ESTUCO Y PRIMERA MANO | 2d | 2015-11-09 | 2015-11-11 | 271FS+6d | 2015-11-03 | 2015-11-04 | 2d | 42d | 0d | CALENDARIO DE TRABAJO MONTERESERVA | 0% | 0% | 0% | 0% |
| 273 | 1.4.5.6 | AFINADO DE PISOS | 2d | 2015-11-11 | 2015-11-13 | 272, 156 | 2015-11-05 | 2015-11-06 | 2d | 42d | 0d | CALENDARIO DE TRABAJO MONTERESERVA | 0% | 0% | 0% | 0% |
| 274 | 1.4.5.7 | DETALLADO Y SEGUNDA MANO | 2d | 2015-11-13 | 2015-11-17 | 273 | 2015-11-07 | 2015-11-09 | 2d | 42d | 0d | CALENDARIO DE TRABAJO MONTERESERVA | 0% | 0% | 0% | 0% |
| 275 | 1.4.5.8 | INSTALACION TAPA SHUT | 2d | 2015-11-17 | 2015-11-19 | 274, 268 | 2015-11-10 | 2015-11-11 | 2d | 42d | 0d | CALENDARIO DE TRABAJO MONTERESERVA | 0% | 0% | 0% | 0% |
| 276 | 1.4.5.9 | INSTALACION DE PISOS | 6d | 2015-11-19 | 2015-11-26 | 275 | 2015-11-12 | 2015-11-19 | 6d | 42d | 0d | CALENDARIO DE TRABAJO MONTERESERVA | 0% | 0% | 0% | 0% |
| 277 | 1.4.5.10 | PASAMANOS | 2d | 2015-11-26 | 2015-11-28 | 276 | 2015-11-20 | 2015-11-21 | 2d | 42d | 0d | CALENDARIO DE TRABAJO MONTERESERVA | 0% | 0% | 0% | 0% |
| 278 | 1.4.5.11 | EQUIPOS CONTRAINCENDIO | 2d | 2015-11-28 | 2015-12-01 | 277 | 2015-11-23 | 2015-11-24 | 2d | 42d | 0d | CALENDARIO DE TRABAJO MONTERESERVA | 0% | 0% | 0% | 0% |
| 279 | 1.4.5.12 | PUERTAS ACCESO EN MADERA | 1d | 2015-12-01 | 2015-12-02 | 278 | 2015-11-25 | 2015-11-25 | 1d | 42d | 0d | CALENDARIO DE TRABAJO MONTERESERVA | 0% | 0% | 0% | 0% |
| 280 | 1.4.5.13 | DETALLADO Y TERCERA MANO DE PINTURA | 2d | 2015-12-02 | 2015-12-04 | 279 | 2015-11-26 | 2015-11-27 | 2d | 42d | 0d | CALENDARIO DE TRABAJO MONTERESERVA | 0% | 0% | 0% | 0% |
| 281 | 1.4.5.14 | ASEO PREENTREGA ( INCLUYE APTO) | 6d | 2015-12-04 | 2015-12-12 | 280 | 2015-11-28 | 2015-12-04 | 6d | 42d |  | CALENDARIO DE TRABAJO MONTERESERVA | 0% | 0% | 0% | 0% |

| ID | WBS | Task | Duration | Start | Finish | Predecessors | Baseline start | Baseline finish | Baseline duration | Total slack | Free slack | Calendar | Text1 | Text2 | Text5 | Text6 |
| --- | --- | --- | --- | --- | --- | --- | --- | --- | --- | --- | --- | --- | --- | --- | --- | --- |
| 282 | 1.4.6 | **PUNTO FIJO P5** | 37d | 2015-10-23 | 2015-12-15 |  | 2015-10-17 | 2015-12-07 | 36d | 24d |  | DIAS CALENDARIO 2 | 0% | 0% | 0% | 0% |
| 283 | 1.4.6.1 | SHUT DE BASURAS | 4d | 2015-10-23 | 2015-10-28 | 284SF | 2015-10-17 | 2015-10-22 | 4d | 57d | 16d | CALENDARIO DE TRABAJO MONTERESERVA | 0% | 0% | 0% | 0% |
| 284 | 1.4.6.2 | REMATES MAMPOSTERIA | 2d | 2015-10-28 | 2015-10-30 | 269, 164 | 2015-10-22 | 2015-10-23 | 2d | 23d | 0d | CALENDARIO DE TRABAJO MONTERESERVA | 0% | 0% | 0% | 0% |
| 285 | 1.4.6.3 | PROLONGACIONES ELECTRICAS | 1d | 2015-10-30 | 2015-10-31 | 284 | 2015-10-24 | 2015-10-24 | 1d | 40d | 0d | CALENDARIO DE TRABAJO MONTERESERVA | 0% | 0% | 0% | 0% |
| 286 | 1.4.6.4 | PAÑETES | 2d | 2015-10-31 | 2015-11-04 | 285 | 2015-10-26 | 2015-10-27 | 2d | 40d | 0d | CALENDARIO DE TRABAJO MONTERESERVA | 0% | 0% | 0% | 0% |
| 287 | 1.4.6.5 | ESTUCO Y PRIMERA MANO | 2d | 2015-11-11 | 2015-11-13 | 286FS+6d | 2015-11-05 | 2015-11-06 | 2d | 40d | 0d | CALENDARIO DE TRABAJO MONTERESERVA | 0% | 0% | 0% | 0% |
| 288 | 1.4.6.6 | AFINADO DE PISOS | 2d | 2015-11-13 | 2015-11-17 | 287, 157 | 2015-11-07 | 2015-11-09 | 2d | 40d | 0d | CALENDARIO DE TRABAJO MONTERESERVA | 0% | 0% | 0% | 0% |
| 289 | 1.4.6.7 | DETALLADO Y SEGUNDA MANO | 2d | 2015-11-17 | 2015-11-19 | 288 | 2015-11-10 | 2015-11-11 | 2d | 40d | 0d | CALENDARIO DE TRABAJO MONTERESERVA | 0% | 0% | 0% | 0% |
| 290 | 1.4.6.8 | INSTALACION TAPA SHUT | 2d | 2015-11-19 | 2015-11-21 | 289, 283 | 2015-11-12 | 2015-11-13 | 2d | 40d | 0d | CALENDARIO DE TRABAJO MONTERESERVA | 0% | 0% | 0% | 0% |
| 291 | 1.4.6.9 | INSTALACION DE PISOS | 6d | 2015-11-21 | 2015-11-28 | 290 | 2015-11-14 | 2015-11-21 | 6d | 40d | 0d | CALENDARIO DE TRABAJO MONTERESERVA | 0% | 0% | 0% | 0% |
| 292 | 1.4.6.10 | PASAMANOS | 2d | 2015-11-28 | 2015-12-01 | 291 | 2015-11-23 | 2015-11-24 | 2d | 40d | 0d | CALENDARIO DE TRABAJO MONTERESERVA | 0% | 0% | 0% | 0% |
| 293 | 1.4.6.11 | EQUIPOS CONTRAINCENDIO | 2d | 2015-12-01 | 2015-12-03 | 292 | 2015-11-25 | 2015-11-26 | 2d | 40d | 0d | CALENDARIO DE TRABAJO MONTERESERVA | 0% | 0% | 0% | 0% |
| 294 | 1.4.6.12 | PUERTAS ACCESO EN MADERA | 1d | 2015-12-03 | 2015-12-04 | 293 | 2015-11-27 | 2015-11-27 | 1d | 40d | 0d | CALENDARIO DE TRABAJO MONTERESERVA | 0% | 0% | 0% | 0% |
| 295 | 1.4.6.13 | DETALLADO Y TERCERA MANO DE PINTURA | 2d | 2015-12-04 | 2015-12-07 | 294 | 2015-11-28 | 2015-11-30 | 2d | 40d | 0d | CALENDARIO DE TRABAJO MONTERESERVA | 0% | 0% | 0% | 0% |
| 296 | 1.4.6.14 | ASEO PREENTREGA ( INCLUYE APTO) | 6d | 2015-12-07 | 2015-12-15 | 295 | 2015-12-01 | 2015-12-07 | 6d | 40d |  | CALENDARIO DE TRABAJO MONTERESERVA | 0% | 0% | 0% | 0% |
| 297 | 1.4.7 | **PUNTO FIJO P6** | 55.48d | 2015-11-06 | 2016-01-23 |  | 2015-10-30 | 2016-01-16 | 56d | 3.52d |  | DIAS CALENDARIO 2 | 0% | 0% | 0% | 0% |
| 298 | 1.4.7.1 | SHUT BASURAS | 4d | 2015-11-06 | 2015-11-11 | 299SF | 2015-10-30 | 2015-11-05 | 4d | 31d | 15d | CALENDARIO DE TRABAJO MONTERESERVA | 0% | 0% | 0% | 0% |
| 299 | 1.4.7.2 | REMATES MAMPOSTERIA | 2d | 2015-11-11 | 2015-11-13 | 284, 165, 192SS | 2015-11-05 | 2015-11-06 | 2d | 14d | 0d | CALENDARIO DE TRABAJO MONTERESERVA | 0% | 0% | 0% | 0% |
| 300 | 1.4.7.3 | PROLONGACIONES ELECTRICAS | 1d | 2015-11-13 | 2015-11-14 | 299 | 2015-11-07 | 2015-11-07 | 1d | 14d | 0d | CALENDARIO DE TRABAJO MONTERESERVA | 0% | 0% | 0% | 0% |
| 301 | 1.4.7.4 | PAÑETES | 2d | 2015-11-14 | 2015-11-18 | 300 | 2015-11-09 | 2015-11-10 | 2d | 14d | 0d | CALENDARIO DE TRABAJO MONTERESERVA | 0% | 0% | 0% | 0% |
| 302 | 1.4.7.5 | AFINADO DE PISOS | 2d | 2015-11-18 | 2015-11-20 | 301, 158 | 2015-11-11 | 2015-11-12 | 2d | 20d | 5d | CALENDARIO DE TRABAJO MONTERESERVA | 0% | 0% | 0% | 0% |
| 303 | 1.4.7.6 | ESTUCO Y PRIMERA MANO | 2d | 2015-11-27 | 2015-11-30 | 301FS+8d, 302 | 2015-11-21 | 2015-11-23 | 2d | 14d | 0d | CALENDARIO DE TRABAJO MONTERESERVA | 0% | 0% | 0% | 0% |
| 304 | 1.4.7.7 | DETALLADO Y SEGUNDA MANO | 2d | 2015-11-30 | 2015-12-02 | 303 | 2015-11-24 | 2015-11-25 | 2d | 14d | 0d | CALENDARIO DE TRABAJO MONTERESERVA | 0% | 0% | 0% | 0% |
| 305 | 1.4.7.8 | INSTALACION TAPA SHUT | 2d | 2015-12-02 | 2015-12-04 | 304, 298 | 2015-11-26 | 2015-11-27 | 2d | 14d | 0d | CALENDARIO DE TRABAJO MONTERESERVA | 0% | 0% | 0% | 0% |
| 306 | 1.4.7.9 | INSTALACION DE PISOS | 6d | 2015-12-04 | 2015-12-12 | 305 | 2015-11-28 | 2015-12-04 | 6d | 14d | 0d | CALENDARIO DE TRABAJO MONTERESERVA | 0% | 0% | 0% | 0% |
| 307 | 1.4.7.10 | PASAMANOS | 2d | 2015-12-12 | 2015-12-15 | 306 | 2015-12-05 | 2015-12-07 | 2d | 14d | 0d | CALENDARIO DE TRABAJO MONTERESERVA | 0% | 0% | 0% | 0% |
| 308 | 1.4.7.11 | EQUIPOS CONTRAINCENDIO | 2d | 2015-12-15 | 2015-12-17 | 307 | 2015-12-09 | 2015-12-10 | 2d | 14d | 0d | CALENDARIO DE TRABAJO MONTERESERVA | 0% | 0% | 0% | 0% |
| 309 | 1.4.7.12 | PUERTAS EN MADERA | 1d | 2015-12-17 | 2015-12-18 | 308 | 2015-12-11 | 2015-12-11 | 1d | 14d | 0d | CALENDARIO DE TRABAJO MONTERESERVA | 0% | 0% | 0% | 0% |
| 310 | 1.4.7.13 | DETALLADO Y TERCERA MANO DE PINTURA | 2d | 2015-12-18 | 2016-01-04 | 309 | 2015-12-12 | 2015-12-14 | 2d | 14d | 9.48d | CALENDARIO DE TRABAJO MONTERESERVA | 0% | 0% | 0% | 0% |
| 311 | 1.4.7.14 | ASEO PREENTREGA ( INCLUYE APTO) | 6d | 2016-01-16 | 2016-01-23 | 310, 183, 360 | 2016-01-09 | 2016-01-16 | 6d | 4d | 0d | CALENDARIO DE TRABAJO MONTERESERVA | 0% | 0% | 0% | 0% |

| ID | WBS | Task | Type | Duration | Start | Finish | Predecessors | Baseline start | Baseline finish | Baseline duration | Total slack | Free slack | Calendar | Text1 | Text2 | Text5 | Text6 |
| --- | --- | --- | --- | --- | --- | --- | --- | --- | --- | --- | --- | --- | --- | --- | --- | --- | --- |
| 312 | 1.5 | **ENTREGAS A PROPIETARIOS ( OBRA GRIS )** |  | 0d | 2016-01-16 | 2016-01-16 |  | 2016-01-08 | 2016-01-08 | 0d | 20.52d |  | DIAS CALENDARIO 2 | 0% | 0% | 0% | 0% |
| 313 | 1.5.1 | **CIERRE APARTAMENTOS EN OBRA GRIS** |  | 0d | 2016-01-16 | 2016-01-16 |  | 2016-01-08 | 2016-01-08 | 0d | 20.52d |  | DIAS CALENDARIO 2 | 0% | 0% | 0% | 0% |
| 314 | 1.5.1.1 | APARTAMENTOS 101 Y 102 | milestone | 0d | 2016-01-16 | 2016-01-16 | 186, 357 | 2016-01-08 | 2016-01-08 | 0d | 20.52d | 0d | DIAS CALENDARIO | 0% | 0% | 0% | 0% |
| 315 | 1.5.1.2 | APARTAMENTOS 201 Y 202 | milestone | 0d | 2016-01-16 | 2016-01-16 | 314, 187 | 2016-01-08 | 2016-01-08 | 0d | 20.52d | 0d | DIAS CALENDARIO | 0% | 0% | 0% | 0% |
| 316 | 1.5.1.3 | APARTAMENTOS 301 Y 302 | milestone | 0d | 2016-01-16 | 2016-01-16 | 315, 188 | 2016-01-08 | 2016-01-08 | 0d | 20.52d | 0d | DIAS CALENDARIO | 0% | 0% | 0% | 0% |
| 317 | 1.5.1.4 | APARTAMENTOS 401 Y 402 | milestone | 0d | 2016-01-16 | 2016-01-16 | 316, 189 | 2016-01-08 | 2016-01-08 | 0d | 20.52d | 0d | DIAS CALENDARIO | 0% | 0% | 0% | 0% |
| 318 | 1.5.1.5 | APARTAMENTOS 501 Y 502 | milestone | 0d | 2016-01-16 | 2016-01-16 | 317, 190 | 2016-01-08 | 2016-01-08 | 0d | 20.52d | 0d | DIAS CALENDARIO | 0% | 0% | 0% | 0% |
| 319 | 1.5.1.6 | APARTAMENTOS 601 Y 602 | milestone | 0d | 2016-01-16 | 2016-01-16 | 318, 192 | 2016-01-08 | 2016-01-08 | 0d | 20.52d |  | DIAS CALENDARIO | 0% | 0% | 0% | 0% |
| 320 | 1.6 | **OBRAS EXTERIORES** |  | 123d | 2015-08-21 | 2016-02-10 |  | 2015-08-14 | 2016-02-03 | 124d | 3d |  | DIAS CALENDARIO 2 | 0% | 0% | 0% | 0% |
| 321 | 1.6.1 | **PARQUEADEROS DE VISITANTES** |  | 49d | 2015-12-03 | 2016-02-10 |  | 2015-11-27 | 2016-02-03 | 49d | 3d |  | DIAS CALENDARIO 2 | 0% | 0% | 0% | 0% |
| 322 | 1.6.1.1 | PARQUEADERO DE VISITANTES |  | 45d | 2015-12-03 | 2016-02-10 | 311FF+15d | 2015-11-27 | 2016-02-03 | 45d | 4d |  | CALENDARIO DE TRABAJO MONTERESERVA | 0% | 0% | 0% | 0% |
| 323 | 1.6.2 | **ACABADOS LOBBY** |  | 74.48d | 2015-10-19 | 2016-01-30 |  | 2015-10-13 | 2016-01-23 | 74d | 10.52d |  | DIAS CALENDARIO 2 | 0% | 0% | 0% | 0% |
| 324 | 1.6.2.1 | ENCHAPES BAÑOS |  | 6d | 2015-10-19 | 2015-10-26 | 325SF+3d | 2015-10-13 | 2015-10-19 | 6d | 80d |  | CALENDARIO DE TRABAJO MONTERESERVA | 0% | 0% | 0% | 0% |
| 325 | 1.6.2.2 | PISOS 1/4 x 26 |  | 12d | 2015-10-22 | 2015-11-06 | 326SF+3d | 2015-10-16 | 2015-10-29 | 12d | 71d | 0d | CALENDARIO DE TRABAJO MONTERESERVA | 0% | 0% | 0% | 0% |
| 326 | 1.6.2.3 | ESTUCO Y PRIMERA MANO DE PINTURA |  | 8d | 2015-11-03 | 2015-11-12 | 327SF+3d | 2015-10-27 | 2015-11-05 | 8d | 66d | 0d | CALENDARIO DE TRABAJO MONTERESERVA | 0% | 0% | 0% | 0% |
| 327 | 1.6.2.4 | INSTALACION PISO HALL DE ASCENSOR |  | 4d | 2015-11-09 | 2015-11-13 | 328SF+3d | 2015-11-03 | 2015-11-06 | 4d | 65d | 0d | CALENDARIO DE TRABAJO MONTERESERVA | 0% | 0% | 0% | 0% |
| 328 | 1.6.2.5 | INSTALACION CIELO EN DRY WALL |  | 18d | 2015-11-10 | 2015-12-02 | 329SF+3d | 2015-11-04 | 2015-11-25 | 18d | 50d | 0d | CALENDARIO DE TRABAJO MONTERESERVA | 0% | 0% | 0% | 0% |
| 329 | 1.6.2.6 | DETALLADO Y SEGUNDA MANO DE PINTURA |  | 10d | 2015-11-28 | 2015-12-11 | 330SF+3d | 2015-11-23 | 2015-12-03 | 10d | 43d | 0d | CALENDARIO DE TRABAJO MONTERESERVA | 0% | 0% | 0% | 0% |
| 330 | 1.6.2.7 | REMATES VENTANERIA |  | 4d | 2015-12-07 | 2015-12-12 | 331SF+3d | 2015-12-01 | 2015-12-04 | 4d | 42d | 0d | CALENDARIO DE TRABAJO MONTERESERVA | 0% | 0% | 0% | 0% |
| 331 | 1.6.2.8 | CARPINTERIA MADERA |  | 18d | 2015-12-09 | 2016-01-14 | 332SF+3d | 2015-12-02 | 2016-01-06 | 18d | 27d | 0d | CALENDARIO DE TRABAJO MONTERESERVA | 0% | 0% | 0% | 0% |
| 332 | 1.6.2.9 | APARATOS SANITARIOS |  | 6d | 2016-01-09 | 2016-01-18 | 333SF+3d | 2016-01-04 | 2016-01-09 | 6d | 24d | 0d | CALENDARIO DE TRABAJO MONTERESERVA | 0% | 0% | 0% | 0% |
| 333 | 1.6.2.10 | INSTALACION GUARDAESCOBA |  | 3d | 2016-01-14 | 2016-01-18 | 334 | 2016-01-07 | 2016-01-09 | 3d | 24d | 0d | CALENDARIO DE TRABAJO MONTERESERVA | 0% | 0% | 0% | 0% |
| 334 | 1.6.2.11 | APARATOS ELECTRICOS |  | 3d | 2016-01-09 | 2016-01-14 | 335SF+2d | 2016-01-04 | 2016-01-06 | 3d | 24d | 0d | CALENDARIO DE TRABAJO MONTERESERVA | 0% | 0% | 0% | 0% |
| 335 | 1.6.2.12 | SEGUNDA MANO DE PINTURA |  | 8d | 2016-01-12 | 2016-01-21 | 336SF+2d | 2016-01-05 | 2016-01-14 | 8d | 21d | 0d | CALENDARIO DE TRABAJO MONTERESERVA | 0% | 0% | 0% | 0% |
| 336 | 1.6.2.13 | DETALLADO FINAL Y TERCERA MANO DE PINTURA |  | 6d | 2016-01-19 | 2016-01-26 | 337SF+2d | 2016-01-13 | 2016-01-19 | 6d | 17d | 0d | CALENDARIO DE TRABAJO MONTERESERVA | 0% | 0% | 0% | 0% |
| 337 | 1.6.2.14 | ASEO FINAL |  | 6d | 2016-01-23 | 2016-01-30 | 311 | 2016-01-18 | 2016-01-23 | 6d | 13d | 0d | CALENDARIO DE TRABAJO MONTERESERVA | 0% | 0% | 0% | 0% |

| ID | WBS | Task | Duration | Start | Finish | Predecessors | Baseline start | Baseline finish | Baseline duration | Total slack | Free slack | Calendar | Text1 | Text2 | Text5 | Text6 |
| --- | --- | --- | --- | --- | --- | --- | --- | --- | --- | --- | --- | --- | --- | --- | --- | --- |
| 338 | 1.6.3 | **ACABADOS NIVEL -SOTANO** | 105.48d | 2015-08-21 | 2016-01-16 |  | 2015-08-14 | 2016-01-08 | 106d | 20.48d |  | DIAS CALENDARIO 2 | 0% | 0% | 0% | 0% |
| 339 | 1.6.3.1 | ADECUACIONES TERRENO | 12d | 2015-08-21 | 2015-09-04 | 132 | 2015-08-14 | 2015-08-28 | 12d | 25d | 0d | CALENDARIO DE TRABAJO MONTERESERVA | 0% | 0% | 0% | 0% |
| 340 | 1.6.3.2 | FILTROS | 12d | 2015-09-04 | 2015-09-18 | 339 | 2015-08-29 | 2015-09-11 | 12d | 25d | 0d | CALENDARIO DE TRABAJO MONTERESERVA | 0% | 0% | 0% | 0% |
| 341 | 1.6.3.3 | RELLENOS | 6d | 2015-09-18 | 2015-09-25 | 340 | 2015-09-12 | 2015-09-18 | 6d | 25d | 0d | CALENDARIO DE TRABAJO MONTERESERVA | 0% | 0% | 0% | 0% |
| 342 | 1.6.3.4 | PAVIMENTOS SOTANO | 6d | 2015-09-25 | 2015-10-02 | 341 | 2015-09-19 | 2015-09-25 | 6d | 25d | 0d | CALENDARIO DE TRABAJO MONTERESERVA | 0% | 0% | 0% | 0% |
| 343 | 1.6.3.5 | PAÑETES SOTANO | 6d | 2015-10-02 | 2015-10-09 | 342 | 2015-09-26 | 2015-10-02 | 6d | 25d | 0d | CALENDARIO DE TRABAJO MONTERESERVA | 0% | 0% | 0% | 0% |
| 344 | 1.6.3.6 | SOBREPISOS EN HALLES | 3d | 2015-10-09 | 2015-10-14 | 343 | 2015-10-03 | 2015-10-06 | 3d | 25d | 0d | CALENDARIO DE TRABAJO MONTERESERVA | 0% | 0% | 0% | 0% |
| 345 | 1.6.3.7 | ENCHAPE CUARTO DE BASURAS BAJO LA TORRE | 3d | 2015-10-14 | 2015-10-17 | 344 | 2015-10-07 | 2015-10-09 | 3d | 25d | 0d | CALENDARIO DE TRABAJO MONTERESERVA | 0% | 0% | 0% | 0% |
| 346 | 1.6.3.8 | ESTUCO Y PRIMERA MANO DE PINTURA | 6d | 2015-10-17 | 2015-10-24 | 345 | 2015-10-10 | 2015-10-17 | 6d | 25d | 0d | CALENDARIO DE TRABAJO MONTERESERVA | 0% | 0% | 0% | 0% |
| 347 | 1.6.3.9 | INSTALACION PISOS CERAMICOS O EN ARCILLA | 3d | 2015-10-24 | 2015-10-28 | 346 | 2015-10-19 | 2015-10-21 | 3d | 25d | 0d | CALENDARIO DE TRABAJO MONTERESERVA | 0% | 0% | 0% | 0% |
| 348 | 1.6.3.10 | INSTALACION CIELO EN DRY WALL | 6d | 2015-10-28 | 2015-11-05 | 347 | 2015-10-22 | 2015-10-28 | 6d | 25d | 0d | CALENDARIO DE TRABAJO MONTERESERVA | 0% | 0% | 0% | 0% |
| 349 | 1.6.3.11 | PUERTAS DEPOSITOS | 2d | 2015-11-05 | 2015-11-07 | 348 | 2015-10-29 | 2015-10-30 | 2d | 25d | 0d | CALENDARIO DE TRABAJO MONTERESERVA | 0% | 0% | 0% | 0% |
| 350 | 1.6.3.12 | INSTALACION TOPELLANTAS | 2d | 2015-11-07 | 2015-11-10 | 349 | 2015-10-31 | 2015-11-03 | 2d | 25d | 0d | CALENDARIO DE TRABAJO MONTERESERVA | 0% | 0% | 0% | 0% |
| 351 | 1.6.3.13 | DEMARCACION PARQUEADEROS | 2d | 2015-11-10 | 2015-11-12 | 350 | 2015-11-04 | 2015-11-05 | 2d | 25d | 0d | CALENDARIO DE TRABAJO MONTERESERVA | 0% | 0% | 0% | 0% |
| 352 | 1.6.3.14 | PINTURAS CIELOS | 12d | 2015-11-12 | 2015-11-27 | 351 | 2015-11-06 | 2015-11-20 | 12d | 25d | 0d | CALENDARIO DE TRABAJO MONTERESERVA |  |  | 0% | 0% |
| 353 | 1.6.3.15 | PINTURAS REFLECTIVAS COLUMNAS | 2d | 2015-11-27 | 2015-11-30 | 352 | 2015-11-21 | 2015-11-23 | 2d | 25d | 0d | CALENDARIO DE TRABAJO MONTERESERVA | 0% | 0% | 0% | 0% |
| 354 | 1.6.3.16 | PINTURAS REFLECTIVAS MUROS | 3d | 2015-11-30 | 2015-12-03 | 353 | 2015-11-24 | 2015-11-26 | 3d | 25d | 0d | CALENDARIO DE TRABAJO MONTERESERVA | 0% | 0% | 0% | 0% |
| 355 | 1.6.3.17 | PUERTA DE ACCESO VEHICULAR | 6d | 2015-12-03 | 2015-12-11 | 354 | 2015-11-27 | 2015-12-03 | 6d | 25d | 0d | CALENDARIO DE TRABAJO MONTERESERVA | 0% | 0% | 0% | 0% |
| 356 | 1.6.3.18 | REMATES GENERALES PINTURA | 12d | 2015-12-11 | 2016-01-08 | 355 | 2015-12-04 | 2015-12-18 | 12d | 25d | 0d | CALENDARIO DE TRABAJO MONTERESERVA | 0% | 0% | 0% | 0% |
| 357 | 1.6.3.19 | ASEO | 6d | 2016-01-08 | 2016-01-16 | 356, 221FF, 397FF | 2015-12-19 | 2016-01-08 | 6d | 25d | 0d | CALENDARIO DE TRABAJO MONTERESERVA | 0% | 0% | 0% | 0% |
| 358 | 1.7 | **EQUIPOS ESPECIALES** | 149.52d | 2015-07-01 | 2016-01-26 |  | 2015-06-23 | 2016-01-19 | 151d | 14d |  | DIAS CALENDARIO 2 | 0% | 0% | 0% | 0% |
| 359 | 1.7.1 | **ASCENSORES** | 90d | 2015-09-14 | 2016-01-16 |  | 2015-09-07 | 2016-01-08 | 90d | 3.52d |  | DIAS CALENDARIO 2 | 0% | 0% | 0% | 0% |
| 360 | 1.7.1.1 | MONTAJE ASCESOR | 90d | 2015-09-14 | 2016-01-16 | 474FF | 2015-09-07 | 2016-01-08 | 90d | 3.52d | 0d | DIAS CALENDARIO | 0% | 0% | 0% | 0% |
| 361 | 1.7.2 | **SUB-ESTACION ELECTRICA** | 53d | 2015-07-01 | 2015-09-14 |  | 2015-06-23 | 2015-09-07 | 54d | 101.52d |  | DIAS CALENDARIO 2 | 0% | 0% | 0% | 0% |
| 362 | 1.7.2.1 | CANALIZACION A SUBESTACION | 61d | 2015-07-01 | 2015-09-14 | 360SF | 2015-06-23 | 2015-09-07 | 61d | 115.52d |  | CALENDARIO DE TRABAJO MONTERESERVA | 0% | 0% | 0% | 0% |

| ID | WBS | Task | Type | Duration | Start | Finish | Predecessors | Baseline start | Baseline finish | Baseline duration | Total slack | Free slack | Calendar | Text1 | Text2 | Text5 | Text6 |
| --- | --- | --- | --- | --- | --- | --- | --- | --- | --- | --- | --- | --- | --- | --- | --- | --- | --- |
| 363 | 1.7.3 | **MEDIDORES ELECTRICOS** |  | 90d | 2015-09-22 | 2016-01-26 |  | 2015-09-16 | 2016-01-19 | 90d | 14d |  | DIAS CALENDARIO 2 | 0% | 0% | 0% | 0% |
| 364 | 1.7.3.1 | INICIO TRAMITES | milestone | 0d | 2015-09-22 | 2015-09-22 | 365SF-60d | 2015-09-16 | 2015-09-16 | 0d | 104d |  | DIAS CALENDARIO | 0% | 0% | 0% | 0% |
| 365 | 1.7.3.2 | CONTADORES |  | 30d | 2015-12-15 | 2016-01-26 | 134FF, 221FF+5d, 500FF | 2015-12-09 | 2016-01-19 | 30d | 14d | 0d | DIAS CALENDARIO | 0% | 0% | 0% | 0% |
| 366 | 1.7.4 | **MEDIDORES DE AGUA** |  | 30d | 2015-12-15 | 2016-01-26 |  | 2015-12-09 | 2016-01-19 | 30d | 14d |  | DIAS CALENDARIO 2 | 0% | 0% | 0% | 0% |
| 367 | 1.7.4.1 | MEDIDORES |  | 30d | 2015-12-15 | 2016-01-26 | 134FF, 221FF+5d, 500FF | 2015-12-09 | 2016-01-19 | 30d | 14d |  | DIAS CALENDARIO | 0% | 0% | 0% | 0% |
| 368 | 1.7.5 | **SISTEMA DE CITOFONIA - CIRCUITO CERRADO DE TV.** |  | 60d | 2015-11-03 | 2016-01-26 |  | 2015-10-28 | 2016-01-19 | 60d | 14d |  | DIAS CALENDARIO 2 | 0% | 0% | 0% | 0% |
| 369 | 1.7.5.1 | SISTEMA DE COMUNICACIÓN PORTERIA - CIRCUITO CERRADO DE TV. |  | 60d | 2015-11-03 | 2016-01-26 | 221FF+5d, 500FF | 2015-10-28 | 2016-01-19 | 60d | 14d |  | DIAS CALENDARIO | 0% | 0% | 0% | 0% |
| 370 | 1.7.6 | **PLANTA DE EMERGENCIA** |  | 58d | 2015-09-14 | 2015-12-02 |  | 2015-09-07 | 2015-11-25 | 58d | 43.52d |  | DIAS CALENDARIO 2 | 0% | 0% | 0% | 0% |
| 371 | 1.7.6.1 | INSTALACION PLANTA DE EMERGENCIA |  | 45d | 2015-09-14 | 2015-11-06 | 360SS | 2015-09-07 | 2015-10-29 | 45d | 49.52d | 0d | CALENDARIO DE TRABAJO MONTERESERVA | 0% | 0% | 0% | 0% |
| 372 | 1.7.6.2 | PRUEBAS PLANTA DE EMERGENCIA |  | 21d | 2015-11-07 | 2015-12-02 | 371 | 2015-10-30 | 2015-11-25 | 21d | 49.52d |  | CALENDARIO DE TRABAJO MONTERESERVA | 0% | 0% | 0% | 0% |
| 373 | 1.5.7 | **ACABADOS 101** |  | 63.52d | 2015-09-05 | 2015-12-03 |  | 2015-08-31 | 2015-11-26 | 64d | 1.52d |  | DIAS CALENDARIO 2 | 0% | 0% | 0% | 0% |
| 374 | 1.5.7.1 | ESTUCO Y PINTURA 1 |  | 6d | 2015-09-12 | 2015-09-19 | 144, 152, 194FS-2d | 2015-09-07 | 2015-09-12 | 6d | 2d | 0d | CALENDARIO DE TRABAJO MONTERESERVA | 0% | 0% | 0% | 0% |
| 375 | 1.5.7.3 | ENCHAPES BAÑOS Y COCINAS |  | 6d | 2015-09-19 | 2015-09-26 | 374 | 2015-09-14 | 2015-09-19 | 6d | 104d |  | CALENDARIO DE TRABAJO MONTERESERVA | 0% | 0% | 0% | 0% |
| 376 | 1.5.7.8 | ESTRUCTURA CIELO RASO |  | 6d | 2015-09-05 | 2015-09-12 | 374SF | 2015-08-31 | 2015-09-07 | 6d | 2d | 1.52d | CALENDARIO DE TRABAJO MONTERESERVA | 0% | 0% | 0% | 0% |
| 377 | 1.5.7.9 | EMPLACADO C.R |  | 6d | 2015-09-15 | 2015-09-22 | 376, 194 | 2015-09-09 | 2015-09-15 | 6d | 0d |  | CALENDARIO DE TRABAJO MONTERESERVA | 0% | 0% | 0% | 0% |
| 378 | 1.5.7.10 | MASILLA C.R |  | 6d | 2015-09-22 | 2015-09-29 | 377 | 2015-09-16 | 2015-09-22 | 6d | 0d |  | CALENDARIO DE TRABAJO MONTERESERVA | 0% | 0% | 0% | 0% |
| 379 | 1.5.7.11 | PINTURA C.R |  | 6d | 2015-09-29 | 2015-10-06 | 378 | 2015-09-23 | 2015-09-29 | 6d | 0d |  | CALENDARIO DE TRABAJO MONTERESERVA | 0% | 0% | 0% | 0% |
| 380 | 1.5.7.12 | PINTURA 2 |  | 8d | 2015-10-06 | 2015-10-16 | 186, 379, 377, 374 | 2015-09-30 | 2015-10-08 | 8d | 0d |  | CALENDARIO DE TRABAJO MONTERESERVA | 0% | 0% | 0% | 0% |
| 381 | 1.5.7.23 | APARATOS SANITARIOS |  | 3d | 2015-10-16 | 2015-10-20 | 380 | 2015-10-09 | 2015-10-13 | 3d | 32d | 0d | CALENDARIO DE TRABAJO MONTERESERVA | 0% | 0% | 0% | 0% |
| 382 | 1.8.9 | DIVISIONES DE DUCHAS |  | 3d | 2015-10-20 | 2015-10-23 | 381 | 2015-10-14 | 2015-10-16 | 3d | 32d | 0d | CALENDARIO DE TRABAJO MONTERESERVA | 0% | 0% | 0% | 0% |
| 383 | 1.8.10 | ASEO PARA INSTALACION PISO |  | 2d | 2015-10-23 | 2015-10-26 | 382 | 2015-10-17 | 2015-10-19 | 2d | 32d | 0d | CALENDARIO DE TRABAJO MONTERESERVA | 0% | 0% | 0% | 0% |
| 384 | 1.8.11 | PRUEBA DE HUMEDAD |  | 2d | 2015-10-26 | 2015-10-28 | 383 | 2015-10-20 | 2015-10-21 | 2d | 32d | 2d | CALENDARIO DE TRABAJO MONTERESERVA | 0% | 0% | 0% | 0% |
| 385 | 1.5.4.15 | MUEBLE SALA Y CLÓSETS |  | 12d | 2015-10-16 | 2015-10-30 | 380 | 2015-10-09 | 2015-10-23 | 12d | 30d | 0d | CALENDARIO DE TRABAJO MONTERESERVA | 0% | 0% | 0% | 0% |
| 386 | 1.5.4.16 | MARCOS Y PUERTAS |  | 10d | 2015-10-16 | 2015-10-28 | 380 | 2015-10-09 | 2015-10-21 | 10d | 10d | 0d | CALENDARIO DE TRABAJO MONTERESERVA | 0% | 0% | 0% | 0% |
| 387 | 1.5.4.17 | CARPINTERÍA COCINA Y BAÑOS |  | 10d | 2015-10-16 | 2015-10-28 | 380 | 2015-10-09 | 2015-10-21 | 10d | 0d |  | CALENDARIO DE TRABAJO MONTERESERVA | 0% | 0% | 0% | 0% |
| 388 | 1.5.4.26 | PISO EN MADERA |  | 6d | 2015-10-30 | 2015-11-07 | 385, 386, 387, 384 | 2015-10-24 | 2015-10-30 | 6d | 30d | 1.52d | CALENDARIO DE TRABAJO MONTERESERVA | 0% | 0% | 0% | 0% |
| 389 | 1.5.4.18 | MARMOL DUCHAS, MESÓN MARMOL Y MUEBLES COCINAS |  | 10d | 2015-10-28 | 2015-11-10 | 387 | 2015-10-22 | 2015-11-03 | 10d | 0d |  | CALENDARIO DE TRABAJO MONTERESERVA | 0% | 0% | 0% | 0% |
| 390 | 1.5.7.24 | GASODOMÉSTICOS |  | 2d | 2015-11-10 | 2015-11-12 | 389 | 2015-11-04 | 2015-11-05 | 2d | 1d |  | CALENDARIO DE TRABAJO MONTERESERVA | 0% | 0% | 0% | 0% |
| 391 | 1.8.18 | ESPEJOS BAÑOS |  | 3d | 2015-11-10 | 2015-11-13 | 389 | 2015-11-04 | 2015-11-06 | 3d | 0d |  | CALENDARIO DE TRABAJO MONTERESERVA | 0% | 0% | 0% | 0% |
| 392 | 1.5.4.25 | ASEO |  | 2d | 2015-11-13 | 2015-11-17 | 391 | 2015-11-07 | 2015-11-09 | 2d | 59d | 0d | CALENDARIO DE TRABAJO MONTERESERVA | 0% | 0% | 0% | 0% |
| 393 | 1.8.20 | INSTALACION GUARDAESCOBA |  | 4d | 2015-11-17 | 2015-11-21 | 392 | 2015-11-10 | 2015-11-13 | 4d | 59d |  | CALENDARIO DE TRABAJO MONTERESERVA | 0% | 0% | 0% | 0% |
| 394 | 1.8.21 | APARATOS ELECRICOS |  | 2d | 2015-11-10 | 2015-11-12 | 389 | 2015-11-04 | 2015-11-05 | 2d | 1d |  | CALENDARIO DE TRABAJO MONTERESERVA | 0% | 0% | 0% | 0% |
| 395 | 1.5.4.22 | PINTURA 3 |  | 8d | 2015-11-13 | 2015-11-24 | 390, 391, 394 | 2015-11-07 | 2015-11-17 | 8d | 0d |  | CALENDARIO DE TRABAJO MONTERESERVA | 0% | 0% | 0% | 0% |
| 396 | 1.5.4.27 | ALFOMBRA |  | 2d | 2015-11-24 | 2015-11-26 | 395 | 2015-11-18 | 2015-11-19 | 2d | 49d | 0d | CALENDARIO DE TRABAJO MONTERESERVA | 0% | 0% | 0% | 0% |
| 397 | 1.5.4.28 | REVISIÓN FINAL Y ENTREGA |  | 6d | 2015-11-26 | 2015-12-03 | 396 | 2015-11-20 | 2015-11-26 | 6d | 49d | 31.48d | CALENDARIO DE TRABAJO MONTERESERVA | 0% | 0% | 0% | 0% |

| ID | WBS | Task | Duration | Start | Finish | Predecessors | Baseline start | Baseline finish | Baseline duration | Total slack | Free slack | Calendar | Text1 | Text2 | Text5 | Text6 |
| --- | --- | --- | --- | --- | --- | --- | --- | --- | --- | --- | --- | --- | --- | --- | --- | --- |
| 398 | 1.5.7 | **ACABADOS 201** | 65.52d | 2015-09-12 | 2015-12-14 |  | 2015-09-07 | 2015-12-05 | 65d | 5d |  | DIAS CALENDARIO 2 | 0% | 0% | 0% | 0% |
| 399 | 1.5.7.1 | ESTUCO Y PINTURA 1 | 6d | 2015-09-19 | 2015-09-26 | 374 | 2015-09-14 | 2015-09-19 | 6d | 4d | 0d | CALENDARIO DE TRABAJO MONTERESERVA | 0% | 0% | 0% | 0% |
| 400 | 1.5.7.3 | ENCHAPES BAÑOS Y COCINAS | 6d | 2015-09-26 | 2015-10-03 | 399 | 2015-09-21 | 2015-09-26 | 6d | 98d |  | CALENDARIO DE TRABAJO MONTERESERVA | 0% | 0% | 0% | 0% |
| 401 | 1.5.7.8 | ESTRUCTURA CIELO RASO | 6d | 2015-09-12 | 2015-09-19 | 399SF | 2015-09-07 | 2015-09-14 | 6d | 6d | 1.52d | CALENDARIO DE TRABAJO MONTERESERVA | 0% | 0% | 0% | 0% |
| 402 | 1.5.7.9 | EMPLACADO C.R | 6d | 2015-09-22 | 2015-09-29 | 401, 377 | 2015-09-16 | 2015-09-22 | 6d | 4d | 0d | CALENDARIO DE TRABAJO MONTERESERVA | 0% | 0% | 0% | 0% |
| 403 | 1.5.7.10 | MASILLA C.R | 6d | 2015-09-29 | 2015-10-06 | 402 | 2015-09-23 | 2015-09-29 | 6d | 4d | 0d | CALENDARIO DE TRABAJO MONTERESERVA | 0% | 0% | 0% | 0% |
| 404 | 1.5.7.11 | PINTURA C.R | 6d | 2015-10-06 | 2015-10-14 | 403 | 2015-09-30 | 2015-10-06 | 6d | 4d | 2d | CALENDARIO DE TRABAJO MONTERESERVA | 0% | 0% | 0% | 0% |
| 405 | 1.5.7.12 | PINTURA 2 | 8d | 2015-10-16 | 2015-10-26 | 404, 380, 402, 187, 399 | 2015-10-09 | 2015-10-19 | 8d | 2d | 0d | CALENDARIO DE TRABAJO MONTERESERVA | 0% | 0% | 0% | 0% |
| 406 | 1.5.7.23 | APARATOS SANITARIOS | 3d | 2015-10-26 | 2015-10-29 | 405 | 2015-10-20 | 2015-10-22 | 3d | 30d | 0d | CALENDARIO DE TRABAJO MONTERESERVA | 0% | 0% | 0% | 0% |
| 407 | 1.9.9 | DIVISIONES DE DUCHAS | 3d | 2015-10-29 | 2015-11-03 | 406 | 2015-10-23 | 2015-10-26 | 3d | 30d | 0d | CALENDARIO DE TRABAJO MONTERESERVA | 0% | 0% | 0% | 0% |
| 408 | 1.9.10 | ASEO PARA INSTALACION PISO | 2d | 2015-11-03 | 2015-11-05 | 407 | 2015-10-27 | 2015-10-28 | 2d | 30d | 0d | CALENDARIO DE TRABAJO MONTERESERVA | 0% | 0% | 0% | 0% |
| 409 | 1.9.11 | PRUEBA DE HUMEDAD | 2d | 2015-11-05 | 2015-11-07 | 408 | 2015-10-29 | 2015-10-30 | 2d | 30d | 1.52d | CALENDARIO DE TRABAJO MONTERESERVA | 0% | 0% | 0% | 0% |
| 410 | 1.5.4.15 | MUEBLE SALA Y CLÓSETS | 12d | 2015-10-26 | 2015-11-10 | 405 | 2015-10-20 | 2015-11-03 | 12d | 28d | 0d | CALENDARIO DE TRABAJO MONTERESERVA | 0% | 0% | 0% | 0% |
| 411 | 1.5.4.16 | MARCOS Y PUERTAS | 10d | 2015-10-28 | 2015-11-10 | 405, 386 | 2015-10-22 | 2015-11-03 | 10d | 10d | 0d | CALENDARIO DE TRABAJO MONTERESERVA | 0% | 0% | 0% | 0% |
| 412 | 1.5.4.17 | CARPINTERÍA COCINA Y BAÑOS | 8d | 2015-10-28 | 2015-11-07 | 405, 387 | 2015-10-22 | 2015-10-30 | 8d | 0d |  | CALENDARIO DE TRABAJO MONTERESERVA | 0% | 0% | 0% | 0% |
| 413 | 1.5.4.26 | PISO EN MADERA | 6d | 2015-11-10 | 2015-11-18 | 409, 410, 411, 412, 388 | 2015-11-04 | 2015-11-10 | 6d | 28d | 3d | CALENDARIO DE TRABAJO MONTERESERVA | 0% | 0% | 0% | 0% |
| 414 | 1.5.4.18 | MARMOL DUCHAS, MESÓN MARMOL Y MUEBLES COCINAS | 10d | 2015-11-07 | 2015-11-20 | 412 | 2015-10-31 | 2015-11-12 | 10d | 0d |  | CALENDARIO DE TRABAJO MONTERESERVA | 0% | 0% | 0% | 0% |
| 415 | 1.5.7.24 | GASODOMÉSTICOS | 2d | 2015-11-20 | 2015-11-23 | 414 | 2015-11-13 | 2015-11-14 | 2d | 1d |  | CALENDARIO DE TRABAJO MONTERESERVA | 0% | 0% | 0% | 0% |
| 416 | 1.9.18 | ESPEJOS BAÑOS | 3d | 2015-11-20 | 2015-11-24 | 414 | 2015-11-13 | 2015-11-17 | 3d | 0d |  | CALENDARIO DE TRABAJO MONTERESERVA | 0% | 0% | 0% | 0% |
| 417 | 1.5.4.25 | ASEO | 2d | 2015-11-24 | 2015-11-26 | 416 | 2015-11-18 | 2015-11-19 | 2d | 51d | 0d | CALENDARIO DE TRABAJO MONTERESERVA | 0% | 0% | 0% | 0% |
| 418 | 1.9.20 | INSTALACION GUARDAESCOBA | 4d | 2015-11-26 | 2015-12-01 | 417 | 2015-11-20 | 2015-11-24 | 4d | 51d |  | CALENDARIO DE TRABAJO MONTERESERVA | 0% | 0% | 0% | 0% |
| 419 | 1.9.21 | APARATOS ELECRICOS | 2d | 2015-11-20 | 2015-11-23 | 414 | 2015-11-13 | 2015-11-14 | 2d | 1d |  | CALENDARIO DE TRABAJO MONTERESERVA | 0% | 0% | 0% | 0% |
| 420 | 1.5.4.22 | PINTURA 3 | 8d | 2015-11-24 | 2015-12-03 | 415, 416, 419, 395 | 2015-11-18 | 2015-11-26 | 8d | 0d |  | CALENDARIO DE TRABAJO MONTERESERVA | 0% | 0% | 0% | 0% |
| 421 | 1.5.4.27 | ALFOMBRA | 2d | 2015-12-03 | 2015-12-05 | 420 | 2015-11-27 | 2015-11-28 | 2d | 41d | 0d | CALENDARIO DE TRABAJO MONTERESERVA | 0% | 0% | 0% | 0% |
| 422 | 1.5.4.28 | REVISIÓN FINAL Y ENTREGA | 6d | 2015-12-05 | 2015-12-14 | 421 | 2015-11-30 | 2015-12-05 | 6d | 41d |  | CALENDARIO DE TRABAJO MONTERESERVA | 0% | 0% | 0% | 0% |

| ID | WBS | Task | Duration | Start | Finish | Predecessors | Baseline start | Baseline finish | Baseline duration | Total slack | Free slack | Calendar | Text1 | Text2 | Text5 | Text6 |
| --- | --- | --- | --- | --- | --- | --- | --- | --- | --- | --- | --- | --- | --- | --- | --- | --- |
| 423 | 1.5.7 | **ACABADOS 301** | 77.52d | 2015-09-19 | 2016-01-06 |  | 2015-09-14 | 2015-12-16 | 68d | 5d |  | DIAS CALENDARIO 2 | 0% | 0% | 0% | 0% |
| 424 | 1.5.7.1 | ESTUCO Y PINTURA 1 | 6d | 2015-09-26 | 2015-10-03 | 399 | 2015-09-21 | 2015-09-26 | 6d | 4d | 0d | CALENDARIO DE TRABAJO MONTERESERVA | 0% | 0% | 0% | 0% |
| 425 | 1.5.7.3 | ENCHAPES BAÑOS Y COCINAS | 6d | 2015-10-03 | 2015-10-10 | 424 | 2015-09-28 | 2015-10-03 | 6d | 92d |  | CALENDARIO DE TRABAJO MONTERESERVA | 0% | 0% | 0% | 0% |
| 426 | 1.10.3 | ACABADOS CHIMENEA | 6d | 2015-09-19 | 2015-09-26 | 424SF | 2015-09-14 | 2015-09-21 | 6d | 26d | 20.52d | CALENDARIO DE TRABAJO MONTERESERVA |  |  | 0% | 0% |
| 427 | 1.5.7.8 | ESTRUCTURA CIELO RASO | 6d | 2015-09-19 | 2015-09-26 | 424SF | 2015-09-14 | 2015-09-21 | 6d | 6d | 1.52d | CALENDARIO DE TRABAJO MONTERESERVA | 0% | 0% | 0% | 0% |
| 428 | 1.5.7.9 | EMPLACADO C.R | 6d | 2015-09-29 | 2015-10-06 | 427, 402 | 2015-09-23 | 2015-09-29 | 6d | 4d | 0d | CALENDARIO DE TRABAJO MONTERESERVA | 0% | 0% | 0% | 0% |
| 429 | 1.5.7.10 | MASILLA C.R | 6d | 2015-10-06 | 2015-10-14 | 428 | 2015-09-30 | 2015-10-06 | 6d | 6d | 0d | CALENDARIO DE TRABAJO MONTERESERVA | 0% | 0% | 0% | 0% |
| 430 | 1.5.7.11 | PINTURA C.R | 6d | 2015-10-14 | 2015-10-21 | 429 | 2015-10-07 | 2015-10-14 | 6d | 6d | 3d | CALENDARIO DE TRABAJO MONTERESERVA | 0% | 0% | 0% | 0% |
| 431 | 1.5.7.12 | PINTURA 2 | 8d | 2015-10-26 | 2015-11-05 | 430, 405, 426, 428, 188, 424 | 2015-10-20 | 2015-10-28 | 8d | 2d | 0d | CALENDARIO DE TRABAJO MONTERESERVA | 0% | 0% | 0% | 0% |
| 432 | 1.5.7.23 | APARATOS SANITARIOS | 3d | 2015-11-05 | 2015-11-09 | 431 | 2015-10-29 | 2015-10-31 | 3d | 28d | 0d | CALENDARIO DE TRABAJO MONTERESERVA | 0% | 0% | 0% | 0% |
| 433 | 1.10.10 | DIVISIONES DE DUCHAS | 3d | 2015-11-09 | 2015-11-12 | 432 | 2015-11-03 | 2015-11-05 | 3d | 28d | 0d | CALENDARIO DE TRABAJO MONTERESERVA | 0% | 0% | 0% | 0% |
| 434 | 1.10.11 | ASEO PARA INSTALACION PISO | 2d | 2015-11-12 | 2015-11-14 | 433 | 2015-11-06 | 2015-11-07 | 2d | 28d | 0d | CALENDARIO DE TRABAJO MONTERESERVA | 0% | 0% | 0% | 0% |
| 435 | 1.10.12 | PRUEBA DE HUMEDAD | 2d | 2015-11-14 | 2015-11-18 | 434 | 2015-11-09 | 2015-11-10 | 2d | 28d | 3d | CALENDARIO DE TRABAJO MONTERESERVA | 0% | 0% | 0% | 0% |
| 436 | 1.5.4.15 | MUEBLE SALA Y CLÓSETS | 12d | 2015-11-05 | 2015-11-20 | 431 | 2015-10-29 | 2015-11-12 | 12d | 26d | 1d | CALENDARIO DE TRABAJO MONTERESERVA | 0% | 0% | 0% | 0% |
| 437 | 1.5.4.16 | MARCOS Y PUERTAS | 10d | 2015-11-10 | 2015-11-23 | 431, 411 | 2015-11-04 | 2015-11-14 | 10d | 10d | 0d | CALENDARIO DE TRABAJO MONTERESERVA | 0% | 0% | 0% | 0% |
| 438 | 1.5.4.17 | CARPINTERÍA COCINA Y BAÑOS | 8d | 2015-11-07 | 2015-11-18 | 431, 412 | 2015-10-31 | 2015-11-10 | 8d | 0d |  | CALENDARIO DE TRABAJO MONTERESERVA | 0% | 0% | 0% | 0% |
| 439 | 1.5.4.26 | PISO EN MADERA | 6d | 2015-11-23 | 2015-11-30 | 435, 436, 437, 438, 413 | 2015-11-17 | 2015-11-23 | 6d | 24d | 4d | CALENDARIO DE TRABAJO MONTERESERVA | 0% | 0% | 0% | 0% |
| 440 | 1.5.4.18 | MARMOL DUCHAS, MESÓN MARMOL Y MUEBLES COCINAS | 10d | 2015-11-18 | 2015-11-30 | 438 | 2015-11-11 | 2015-11-23 | 10d | 0d |  | CALENDARIO DE TRABAJO MONTERESERVA | 0% | 0% | 0% | 0% |
| 441 | 1.5.7.24 | GASODOMÉSTICOS | 2d | 2015-11-30 | 2015-12-02 | 440 | 2015-11-24 | 2015-11-25 | 2d | 1d |  | CALENDARIO DE TRABAJO MONTERESERVA | 0% | 0% | 0% | 0% |
| 442 | 1.10.19 | ESPEJOS BAÑOS | 3d | 2015-11-30 | 2015-12-03 | 440 | 2015-11-24 | 2015-11-26 | 3d | 0d |  | CALENDARIO DE TRABAJO MONTERESERVA | 0% | 0% | 0% | 0% |
| 443 | 1.5.4.25 | ASEO | 2d | 2015-12-03 | 2015-12-05 | 442 | 2015-11-27 | 2015-11-28 | 2d | 43d | 0d | CALENDARIO DE TRABAJO MONTERESERVA | 0% | 0% | 0% | 0% |
| 444 | 1.10.21 | INSTALACION GUARDAESCOBA | 4d | 2015-12-05 | 2015-12-11 | 443 | 2015-11-30 | 2015-12-03 | 4d | 43d |  | CALENDARIO DE TRABAJO MONTERESERVA | 0% | 0% | 0% | 0% |
| 445 | 1.10.22 | APARATOS ELECRICOS | 2d | 2015-11-30 | 2015-12-02 | 440 | 2015-11-24 | 2015-11-25 | 2d | 1d |  | CALENDARIO DE TRABAJO MONTERESERVA | 0% | 0% | 0% | 0% |
| 446 | 1.5.4.22 | PINTURA 3 | 8d | 2015-12-03 | 2015-12-14 | 441, 442, 445, 420 | 2015-11-27 | 2015-12-05 | 8d | 0d |  | CALENDARIO DE TRABAJO MONTERESERVA | 0% | 0% | 0% | 0% |
| 447 | 1.5.4.27 | ALFOMBRA | 2d | 2015-12-14 | 2015-12-16 | 446 | 2015-12-07 | 2015-12-09 | 2d | 33d | 0d | CALENDARIO DE TRABAJO MONTERESERVA | 0% | 0% | 0% | 0% |
| 448 | 1.5.4.28 | REVISIÓN FINAL Y ENTREGA | 6d | 2015-12-16 | 2016-01-06 | 447 | 2015-12-10 | 2015-12-16 | 6d | 33d |  | CALENDARIO DE TRABAJO MONTERESERVA | 0% | 0% | 0% | 0% |

| ID | WBS | Task | Duration | Start | Finish | Predecessors | Baseline start | Baseline finish | Baseline duration | Total slack | Free slack | Calendar | Text1 | Text2 | Text5 | Text6 |
| --- | --- | --- | --- | --- | --- | --- | --- | --- | --- | --- | --- | --- | --- | --- | --- | --- |
| 449 | 1.5.7 | **ACABADOS 401** | 80d | 2015-09-26 | 2016-01-16 |  | 2015-09-21 | 2016-01-08 | 80d | 5d |  | DIAS CALENDARIO 2 | 0% | 0% | 0% | 0% |
| 450 | 1.5.7.1 | ESTUCO Y PINTURA 1 | 6d | 2015-10-03 | 2015-10-10 | 424 | 2015-09-28 | 2015-10-03 | 6d | 4d | 0d | CALENDARIO DE TRABAJO MONTERESERVA | 0% | 0% | 0% | 0% |
| 451 | 1.5.7.3 | ENCHAPES BAÑOS Y COCINAS | 6d | 2015-10-10 | 2015-10-19 | 450 | 2015-10-05 | 2015-10-10 | 6d | 86d |  | CALENDARIO DE TRABAJO MONTERESERVA | 0% | 0% | 0% | 0% |
| 452 | 1.11.3 | ACABADOS CHIMENEA | 6d | 2015-09-26 | 2015-10-03 | 450SF | 2015-09-21 | 2015-09-28 | 6d | 28d | 23.52d | CALENDARIO DE TRABAJO MONTERESERVA |  |  | 0% | 0% |
| 453 | 1.5.7.8 | ESTRUCTURA CIELO RASO | 6d | 2015-09-26 | 2015-10-03 | 450SF | 2015-09-21 | 2015-09-28 | 6d | 6d | 1.52d | CALENDARIO DE TRABAJO MONTERESERVA | 0% | 0% | 0% | 0% |
| 454 | 1.5.7.9 | EMPLACADO C.R | 6d | 2015-10-06 | 2015-10-14 | 453, 428 | 2015-09-30 | 2015-10-06 | 6d | 4d | 0d | CALENDARIO DE TRABAJO MONTERESERVA | 0% | 0% | 0% | 0% |
| 455 | 1.5.7.10 | MASILLA C.R | 6d | 2015-10-14 | 2015-10-21 | 454 | 2015-10-07 | 2015-10-14 | 6d | 8d | 0d | CALENDARIO DE TRABAJO MONTERESERVA | 0% | 0% | 0% | 0% |
| 456 | 1.5.7.11 | PINTURA C.R | 6d | 2015-10-21 | 2015-10-28 | 455 | 2015-10-15 | 2015-10-21 | 6d | 8d | 6d | CALENDARIO DE TRABAJO MONTERESERVA | 0% | 0% | 0% | 0% |
| 457 | 1.5.7.12 | PINTURA 2 | 8d | 2015-11-05 | 2015-11-14 | 452, 456, 431, 454, 189, 450 | 2015-10-29 | 2015-11-07 | 8d | 2d | 0d | CALENDARIO DE TRABAJO MONTERESERVA | 0% | 0% | 0% | 0% |
| 458 | 1.5.7.23 | APARATOS SANITARIOS | 3d | 2015-11-14 | 2015-11-19 | 457 | 2015-11-09 | 2015-11-11 | 3d | 26d | 0d | CALENDARIO DE TRABAJO MONTERESERVA | 0% | 0% | 0% | 0% |
| 459 | 1.11.10 | DIVISIONES DE DUCHAS | 3d | 2015-11-19 | 2015-11-23 | 458 | 2015-11-12 | 2015-11-14 | 3d | 26d | 0d | CALENDARIO DE TRABAJO MONTERESERVA | 0% | 0% | 0% | 0% |
| 460 | 1.11.11 | ASEO PARA INSTALACION PISO | 2d | 2015-11-23 | 2015-11-25 | 459 | 2015-11-17 | 2015-11-18 | 2d | 26d | 0d | CALENDARIO DE TRABAJO MONTERESERVA | 0% | 0% | 0% | 0% |
| 461 | 1.11.12 | PRUEBA DE HUMEDAD | 2d | 2015-11-25 | 2015-11-27 | 460 | 2015-11-19 | 2015-11-20 | 2d | 26d | 5d | CALENDARIO DE TRABAJO MONTERESERVA | 0% | 0% | 0% | 0% |
| 462 | 1.5.4.15 | MUEBLE SALA Y CLÓSETS | 12d | 2015-11-14 | 2015-11-30 | 457 | 2015-11-09 | 2015-11-23 | 12d | 24d | 4d | CALENDARIO DE TRABAJO MONTERESERVA | 0% | 0% | 0% | 0% |
| 463 | 1.5.4.16 | MARCOS Y PUERTAS | 10d | 2015-11-23 | 2015-12-04 | 457, 437 | 2015-11-17 | 2015-11-27 | 10d | 10d | 0d | CALENDARIO DE TRABAJO MONTERESERVA | 0% | 0% | 0% | 0% |
| 464 | 1.5.4.17 | CARPINTERÍA COCINA Y BAÑOS | 8d | 2015-11-18 | 2015-11-27 | 457, 438 | 2015-11-11 | 2015-11-20 | 8d | 0d |  | CALENDARIO DE TRABAJO MONTERESERVA | 0% | 0% | 0% | 0% |
| 465 | 1.5.4.26 | PISO EN MADERA | 6d | 2015-12-04 | 2015-12-12 | 461, 462, 463, 464, 439 | 2015-11-28 | 2015-12-04 | 6d | 20d | 3.52d | CALENDARIO DE TRABAJO MONTERESERVA | 0% | 0% | 0% | 0% |
| 466 | 1.5.4.18 | MARMOL DUCHAS, MESÓN MARMOL Y MUEBLES COCINAS | 10d | 2015-11-27 | 2015-12-10 | 464 | 2015-11-21 | 2015-12-02 | 10d | 0d |  | CALENDARIO DE TRABAJO MONTERESERVA | 0% | 0% | 0% | 0% |
| 467 | 1.5.7.24 | GASODOMÉSTICOS | 2d | 2015-12-10 | 2015-12-12 | 466 | 2015-12-03 | 2015-12-04 | 2d | 1d | 0.52d | CALENDARIO DE TRABAJO MONTERESERVA | 0% | 0% | 0% | 0% |
| 468 | 1.11.19 | ESPEJOS BAÑOS | 3d | 2015-12-10 | 2015-12-14 | 466 | 2015-12-03 | 2015-12-05 | 3d | 0d |  | CALENDARIO DE TRABAJO MONTERESERVA | 0% | 0% | 0% | 0% |
| 469 | 1.5.4.25 | ASEO | 2d | 2015-12-14 | 2015-12-16 | 468 | 2015-12-07 | 2015-12-09 | 2d | 35d | 0d | CALENDARIO DE TRABAJO MONTERESERVA | 0% | 0% | 0% | 0% |
| 470 | 1.11.21 | INSTALACION GUARDAESCOBA | 4d | 2015-12-16 | 2016-01-04 | 469 | 2015-12-10 | 2015-12-14 | 4d | 35d |  | CALENDARIO DE TRABAJO MONTERESERVA | 0% | 0% | 0% | 0% |
| 471 | 1.11.22 | APARATOS ELECRICOS | 2d | 2015-12-10 | 2015-12-12 | 466 | 2015-12-03 | 2015-12-04 | 2d | 1d | 0.52d | CALENDARIO DE TRABAJO MONTERESERVA | 0% | 0% | 0% | 0% |
| 472 | 1.5.4.22 | PINTURA 3 | 8d | 2015-12-14 | 2016-01-06 | 467, 468, 471, 446 | 2015-12-07 | 2015-12-16 | 8d | 0d |  | CALENDARIO DE TRABAJO MONTERESERVA | 0% | 0% | 0% | 0% |
| 473 | 1.5.4.27 | ALFOMBRA | 2d | 2016-01-06 | 2016-01-08 | 472 | 2015-12-17 | 2015-12-18 | 2d | 4d | 0d | CALENDARIO DE TRABAJO MONTERESERVA | 0% | 0% | 0% | 0% |
| 474 | 1.5.4.28 | REVISIÓN FINAL Y ENTREGA | 6d | 2016-01-08 | 2016-01-16 | 473 | 2015-12-19 | 2016-01-08 | 6d | 4d | 0d | CALENDARIO DE TRABAJO MONTERESERVA | 0% | 0% | 0% | 0% |

| ID | WBS | Task | Duration | Start | Finish | Predecessors | Baseline start | Baseline finish | Baseline duration | Total slack | Free slack | Calendar | Text1 | Text2 | Text5 | Text6 |
| --- | --- | --- | --- | --- | --- | --- | --- | --- | --- | --- | --- | --- | --- | --- | --- | --- |
| 475 | 1.5.7 | **ACABADOS 501** | 81.52d | 2015-10-03 | 2016-01-26 |  | 2015-09-28 | 2016-01-19 | 82d | 5d |  | DIAS CALENDARIO 2 | 0% | 0% | 0% | 0% |
| 476 | 1.5.7.1 | ESTUCO Y PINTURA 1 | 6d | 2015-10-10 | 2015-10-19 | 450 | 2015-10-05 | 2015-10-10 | 6d | 4d | 0d | CALENDARIO DE TRABAJO MONTERESERVA | 0% | 0% | 0% | 0% |
| 477 | 1.5.7.3 | ENCHAPES BAÑOS Y COCINAS | 6d | 2015-10-19 | 2015-10-26 | 476 | 2015-10-13 | 2015-10-19 | 6d | 80d |  | CALENDARIO DE TRABAJO MONTERESERVA | 0% | 0% | 0% | 0% |
| 478 | 1.12.3 | ACABADOS CHIMENEA | 6d | 2015-10-03 | 2015-10-10 | 476SF | 2015-09-28 | 2015-10-05 | 6d | 30d | 25d | CALENDARIO DE TRABAJO MONTERESERVA |  |  | 0% | 0% |
| 479 | 1.5.7.8 | ESTRUCTURA CIELO RASO | 6d | 2015-10-03 | 2015-10-10 | 476SF | 2015-09-28 | 2015-10-05 | 6d | 6d | 2.52d | CALENDARIO DE TRABAJO MONTERESERVA | 0% | 0% | 0% | 0% |
| 480 | 1.5.7.9 | EMPLACADO C.R | 6d | 2015-10-14 | 2015-10-21 | 479, 454 | 2015-10-07 | 2015-10-14 | 6d | 4d | 0d | CALENDARIO DE TRABAJO MONTERESERVA | 0% | 0% | 0% | 0% |
| 481 | 1.5.7.10 | MASILLA C.R | 6d | 2015-10-21 | 2015-10-28 | 480 | 2015-10-15 | 2015-10-21 | 6d | 10d | 0d | CALENDARIO DE TRABAJO MONTERESERVA | 0% | 0% | 0% | 0% |
| 482 | 1.5.7.11 | PINTURA C.R | 6d | 2015-10-28 | 2015-11-05 | 481 | 2015-10-22 | 2015-10-28 | 6d | 10d | 6.48d | CALENDARIO DE TRABAJO MONTERESERVA | 0% | 0% | 0% | 0% |
| 483 | 1.5.7.12 | PINTURA 2 | 8d | 2015-11-14 | 2015-11-25 | 478, 482, 457, 480, 190, 476 | 2015-11-09 | 2015-11-18 | 8d | 2d | 0d | CALENDARIO DE TRABAJO MONTERESERVA | 0% | 0% | 0% | 0% |
| 484 | 1.5.7.23 | APARATOS SANITARIOS | 3d | 2015-11-25 | 2015-11-28 | 483 | 2015-11-19 | 2015-11-21 | 3d | 24d | 0d | CALENDARIO DE TRABAJO MONTERESERVA | 0% | 0% | 0% | 0% |
| 485 | 1.12.10 | DIVISIONES DE DUCHAS | 3d | 2015-11-28 | 2015-12-02 | 484 | 2015-11-23 | 2015-11-25 | 3d | 24d | 0d | CALENDARIO DE TRABAJO MONTERESERVA | 0% | 0% | 0% | 0% |
| 486 | 1.12.11 | ASEO PARA INSTALACION PISO | 2d | 2015-12-02 | 2015-12-04 | 485 | 2015-11-26 | 2015-11-27 | 2d | 24d | 0d | CALENDARIO DE TRABAJO MONTERESERVA | 0% | 0% | 0% | 0% |
| 487 | 1.12.12 | PRUEBA DE HUMEDAD | 2d | 2015-12-04 | 2015-12-07 | 486 | 2015-11-28 | 2015-11-30 | 2d | 24d | 8d | CALENDARIO DE TRABAJO MONTERESERVA | 0% | 0% | 0% | 0% |
| 488 | 1.5.4.15 | MUEBLE SALA Y CLÓSETS | 12d | 2015-11-25 | 2015-12-10 | 483 | 2015-11-19 | 2015-12-02 | 12d | 22d | 5d | CALENDARIO DE TRABAJO MONTERESERVA | 0% | 0% | 0% | 0% |
| 489 | 1.5.4.16 | MARCOS Y PUERTAS | 10d | 2015-12-04 | 2015-12-17 | 483, 463 | 2015-11-28 | 2015-12-10 | 10d | 10d | 0d | CALENDARIO DE TRABAJO MONTERESERVA | 0% | 0% | 0% | 0% |
| 490 | 1.5.4.17 | CARPINTERÍA COCINA Y BAÑOS | 8d | 2015-11-27 | 2015-12-07 | 483, 464 | 2015-11-21 | 2015-11-30 | 8d | 0d |  | CALENDARIO DE TRABAJO MONTERESERVA | 0% | 0% | 0% | 0% |
| 491 | 1.5.4.26 | PISO EN MADERA | 6d | 2015-12-17 | 2016-01-07 | 487, 488, 489, 490, 465 | 2015-12-11 | 2015-12-17 | 6d | 16d | 4d | CALENDARIO DE TRABAJO MONTERESERVA | 0% | 0% | 0% | 0% |
| 492 | 1.5.4.18 | MARMOL DUCHAS, MESÓN MARMOL Y MUEBLES COCINAS | 10d | 2015-12-07 | 2015-12-19 | 490 | 2015-12-01 | 2015-12-12 | 10d | 0d |  | CALENDARIO DE TRABAJO MONTERESERVA | 0% | 0% | 0% | 0% |
| 493 | 1.5.7.24 | GASODOMÉSTICOS | 2d | 2015-12-19 | 2016-01-05 | 492 | 2015-12-14 | 2015-12-15 | 2d | 1d |  | CALENDARIO DE TRABAJO MONTERESERVA | 0% | 0% | 0% | 0% |
| 494 | 1.12.19 | ESPEJOS BAÑOS | 3d | 2015-12-19 | 2016-01-06 | 492 | 2015-12-14 | 2015-12-16 | 3d | 0d |  | CALENDARIO DE TRABAJO MONTERESERVA | 0% | 0% | 0% | 0% |
| 495 | 1.5.4.25 | ASEO | 2d | 2016-01-06 | 2016-01-08 | 494 | 2015-12-17 | 2015-12-18 | 2d | 27d | 0d | CALENDARIO DE TRABAJO MONTERESERVA | 0% | 0% | 0% | 0% |
| 496 | 1.12.21 | INSTALACION GUARDAESCOBA | 4d | 2016-01-08 | 2016-01-14 | 495 | 2015-12-19 | 2016-01-06 | 4d | 27d |  | CALENDARIO DE TRABAJO MONTERESERVA | 0% | 0% | 0% | 0% |
| 497 | 1.12.22 | APARATOS ELECRICOS | 2d | 2015-12-19 | 2016-01-05 | 492 | 2015-12-14 | 2015-12-15 | 2d | 1d |  | CALENDARIO DE TRABAJO MONTERESERVA | 0% | 0% | 0% | 0% |
| 498 | 1.5.4.22 | PINTURA 3 | 8d | 2016-01-06 | 2016-01-16 | 493, 494, 497, 472 | 2015-12-17 | 2016-01-08 | 8d | 0d |  | CALENDARIO DE TRABAJO MONTERESERVA | 0% | 0% | 0% | 0% |
| 499 | 1.5.4.27 | ALFOMBRA | 2d | 2016-01-16 | 2016-01-19 | 498 | 2016-01-09 | 2016-01-12 | 2d | 17d | 0d | CALENDARIO DE TRABAJO MONTERESERVA | 0% | 0% | 0% | 0% |
| 500 | 1.5.4.28 | REVISIÓN FINAL Y ENTREGA | 6d | 2016-01-19 | 2016-01-26 | 499 | 2016-01-13 | 2016-01-19 | 6d | 17d | 0d | CALENDARIO DE TRABAJO MONTERESERVA | 0% | 0% | 0% | 0% |

| ID | WBS | Task | Duration | Start | Finish | Predecessors | Baseline start | Baseline finish | Baseline duration | Total slack | Free slack | Calendar | Text1 | Text2 | Text5 | Text6 |
| --- | --- | --- | --- | --- | --- | --- | --- | --- | --- | --- | --- | --- | --- | --- | --- | --- |
| 501 | 1.5.7 | **ACABADOS 601( BAJILLO )** | 88d | 2015-10-06 | 2016-02-05 |  | 2015-09-30 | 2016-01-29 | 88d | 6d |  | DIAS CALENDARIO 2 | 0% | 0% | 0% | 0% |
| 502 | 1.5.7.1 | ESTUCO Y PINTURA 1 | 10d | 2015-10-19 | 2015-10-30 | 476 | 2015-10-13 | 2015-10-23 | 10d | 4d | 0d | CALENDARIO DE TRABAJO MONTERESERVA | 0% | 0% | 0% | 0% |
| 503 | 1.5.7.3 | ENCHAPES BAÑOS Y COCINAS | 6d | 2015-10-30 | 2015-11-07 | 502 | 2015-10-24 | 2015-10-30 | 6d | 70d |  | CALENDARIO DE TRABAJO MONTERESERVA | 0% | 0% | 0% | 0% |
| 504 | 1.13.3 | ACABADOS CHIMENEA | 6d | 2015-10-10 | 2015-10-19 | 502SF | 2015-10-05 | 2015-10-13 | 6d | 32d | 27d | CALENDARIO DE TRABAJO MONTERESERVA |  |  | 0% | 0% |
| 505 | 1.5.7.8 | ESTRUCTURA CIELO RASO | 10d | 2015-10-06 | 2015-10-19 | 502SF | 2015-09-30 | 2015-10-13 | 10d | 6d | 2d | CALENDARIO DE TRABAJO MONTERESERVA | 0% | 0% | 0% | 0% |
| 506 | 1.5.7.9 | EMPLACADO C.R | 8d | 2015-10-21 | 2015-10-30 | 505, 480 | 2015-10-15 | 2015-10-23 | 8d | 4d | 0d | CALENDARIO DE TRABAJO MONTERESERVA | 0% | 0% | 0% | 0% |
| 507 | 1.5.7.10 | MASILLA C.R | 10d | 2015-10-30 | 2015-11-12 | 506 | 2015-10-24 | 2015-11-05 | 10d | 4d | 0d | CALENDARIO DE TRABAJO MONTERESERVA | 0% | 0% | 0% | 0% |
| 508 | 1.5.7.11 | PINTURA C.R | 8d | 2015-11-12 | 2015-11-23 | 507 | 2015-11-06 | 2015-11-14 | 8d | 4d | 2d | CALENDARIO DE TRABAJO MONTERESERVA | 0% | 0% | 0% | 0% |
| 509 | 1.5.7.12 | PINTURA 2 | 9d | 2015-11-25 | 2015-12-05 | 504, 508, 483, 506, 191, 502 | 2015-11-19 | 2015-11-28 | 9d | 2d | 0d | CALENDARIO DE TRABAJO MONTERESERVA | 0% | 0% | 0% | 0% |
| 510 | 1.5.7.23 | APARATOS SANITARIOS | 3d | 2015-12-05 | 2015-12-10 | 509 | 2015-11-30 | 2015-12-02 | 3d | 21d | 0d | CALENDARIO DE TRABAJO MONTERESERVA | 0% | 0% | 0% | 0% |
| 511 | 1.13.10 | DIVISIONES DE DUCHAS | 3d | 2015-12-10 | 2015-12-14 | 510 | 2015-12-03 | 2015-12-05 | 3d | 21d | 0d | CALENDARIO DE TRABAJO MONTERESERVA | 0% | 0% | 0% | 0% |
| 512 | 1.13.11 | ASEO PARA INSTALACION PISO | 2d | 2015-12-14 | 2015-12-16 | 511 | 2015-12-07 | 2015-12-09 | 2d | 21d | 0d | CALENDARIO DE TRABAJO MONTERESERVA | 0% | 0% | 0% | 0% |
| 513 | 1.13.12 | PRUEBA DE HUMEDAD | 2d | 2015-12-16 | 2015-12-18 | 512 | 2015-12-10 | 2015-12-11 | 2d | 21d | 18d | CALENDARIO DE TRABAJO MONTERESERVA | 0% | 0% | 0% | 0% |
| 514 | 1.5.4.15 | MUEBLE SALA Y CLÓSETS | 12d | 2015-12-05 | 2016-01-04 | 509 | 2015-11-30 | 2015-12-14 | 12d | 19d | 7d | CALENDARIO DE TRABAJO MONTERESERVA | 0% | 0% | 0% | 0% |
| 515 | 1.5.4.16 | MARCOS Y PUERTAS | 10d | 2015-12-17 | 2016-01-13 | 509, 489 | 2015-12-11 | 2016-01-05 | 10d | 10d | 0d | CALENDARIO DE TRABAJO MONTERESERVA | 0% | 0% | 0% | 0% |
| 516 | 1.5.4.17 | CARPINTERÍA COCINA Y BAÑOS | 8d | 2015-12-07 | 2015-12-17 | 509, 490 | 2015-12-01 | 2015-12-10 | 8d | 1d | 0d | CALENDARIO DE TRABAJO MONTERESERVA | 0% | 0% | 0% | 0% |
| 517 | 1.5.4.26 | PISO EN MADERA | 8d | 2016-01-13 | 2016-01-22 | 513, 514, 515, 516, 491 | 2016-01-06 | 2016-01-15 | 8d | 12d | 1d | CALENDARIO DE TRABAJO MONTERESERVA | 0% | 0% | 0% | 0% |
| 518 | 1.5.4.18 | MARMOL DUCHAS, MESÓN MARMOL Y MUEBLES COCINAS | 10d | 2015-12-17 | 2016-01-13 | 516 | 2015-12-11 | 2016-01-05 | 10d | 1d | 0d | CALENDARIO DE TRABAJO MONTERESERVA | 0% | 0% | 0% | 0% |
| 519 | 1.5.7.24 | GASODOMÉSTICOS | 2d | 2016-01-13 | 2016-01-15 | 518 | 2016-01-06 | 2016-01-07 | 2d | 1d | 0.48d | CALENDARIO DE TRABAJO MONTERESERVA | 0% | 0% | 0% | 0% |
| 520 | 1.13.19 | ESPEJOS BAÑOS | 2d | 2016-01-13 | 2016-01-15 | 518 | 2016-01-06 | 2016-01-07 | 2d | 1d | 0d | CALENDARIO DE TRABAJO MONTERESERVA | 0% | 0% | 0% | 0% |
| 521 | 1.5.4.25 | ASEO | 2d | 2016-01-15 | 2016-01-18 | 520 | 2016-01-08 | 2016-01-09 | 2d | 19d | 0d | CALENDARIO DE TRABAJO MONTERESERVA | 0% | 0% | 0% | 0% |
| 522 | 1.13.21 | INSTALACION GUARDAESCOBA | 5d | 2016-01-18 | 2016-01-23 | 521 | 2016-01-12 | 2016-01-16 | 5d | 19d |  | CALENDARIO DE TRABAJO MONTERESERVA | 0% | 0% | 0% | 0% |
| 523 | 1.13.22 | APARATOS ELECRICOS | 2d | 2016-01-13 | 2016-01-15 | 518 | 2016-01-06 | 2016-01-07 | 2d | 1d | 0.48d | CALENDARIO DE TRABAJO MONTERESERVA | 0% | 0% | 0% | 0% |
| 524 | 1.5.4.22 | PINTURA 3 | 8d | 2016-01-16 | 2016-01-26 | 519, 520, 523, 498 | 2016-01-09 | 2016-01-19 | 8d | 0d |  | CALENDARIO DE TRABAJO MONTERESERVA | 0% | 0% | 0% | 0% |
| 525 | 1.5.4.27 | ALFOMBRA | 3d | 2016-01-26 | 2016-01-29 | 524 | 2016-01-20 | 2016-01-22 | 3d | 8d | 0d | CALENDARIO DE TRABAJO MONTERESERVA | 0% | 0% | 0% | 0% |
| 526 | 1.5.4.28 | REVISIÓN FINAL Y ENTREGA | 6d | 2016-01-29 | 2016-02-05 | 525 | 2016-01-23 | 2016-01-29 | 6d | 8d |  | CALENDARIO DE TRABAJO MONTERESERVA | 0% | 0% | 0% | 0% |

| ID | WBS | Task | Duration | Start | Finish | Predecessors | Baseline start | Baseline finish | Baseline duration | Total slack | Free slack | Calendar | Text1 | Text2 | Text5 | Text6 |
| --- | --- | --- | --- | --- | --- | --- | --- | --- | --- | --- | --- | --- | --- | --- | --- | --- |
| 527 | 1.5.7 | **ACABADOS 601 ( ALTILLO )** | 81d | 2015-10-23 | 2016-02-15 |  | 2015-10-17 | 2016-02-08 | 81d | 0d |  | DIAS CALENDARIO 2 | 0% | 0% | 0% | 0% |
| 528 | 1.5.7.1 | ESTUCO Y PINTURA 1 | 10d | 2015-10-30 | 2015-11-12 | 502 | 2015-10-24 | 2015-11-05 | 10d | 4d | 0d | CALENDARIO DE TRABAJO MONTERESERVA | 0% | 0% | 0% | 0% |
| 529 | 1.5.7.3 | ENCHAPES BAÑOS Y COCINAS | 6d | 2015-11-12 | 2015-11-20 | 528 | 2015-11-06 | 2015-11-12 | 6d | 60d |  | CALENDARIO DE TRABAJO MONTERESERVA | 0% | 0% | 0% | 0% |
| 530 | 1.14.3 | ACABADOS CHIMENEA | 6d | 2015-10-23 | 2015-10-30 | 528SF | 2015-10-17 | 2015-10-24 | 6d | 32d | 25.48d | CALENDARIO DE TRABAJO MONTERESERVA |  |  | 0% | 0% |
| 531 | 1.5.7.8 | ESTRUCTURA CIELO RASO | 6d | 2015-10-23 | 2015-10-30 | 528SF | 2015-10-17 | 2015-10-24 | 6d | 4d | 0d | CALENDARIO DE TRABAJO MONTERESERVA | 0% | 0% | 0% | 0% |
| 532 | 1.5.7.9 | EMPLACADO C.R | 10d | 2015-10-30 | 2015-11-12 | 531, 506 | 2015-10-24 | 2015-11-05 | 10d | 4d | 0d | CALENDARIO DE TRABAJO MONTERESERVA | 0% | 0% | 0% | 0% |
| 533 | 1.5.7.10 | MASILLA C.R | 10d | 2015-11-12 | 2015-11-25 | 532 | 2015-11-06 | 2015-11-18 | 10d | 4d | 0d | CALENDARIO DE TRABAJO MONTERESERVA | 0% | 0% | 0% | 0% |
| 534 | 1.5.7.11 | PINTURA C.R | 8d | 2015-11-25 | 2015-12-04 | 533 | 2015-11-19 | 2015-11-27 | 8d | 4d | 0.48d | CALENDARIO DE TRABAJO MONTERESERVA | 0% | 0% | 0% | 0% |
| 535 | 1.5.7.12 | PINTURA 2 | 9d | 2015-12-05 | 2015-12-17 | 530, 534, 532, 192, 528, 509 | 2015-11-30 | 2015-12-10 | 9d | 3d | 0d | CALENDARIO DE TRABAJO MONTERESERVA | 0% | 0% | 0% | 0% |
| 536 | 1.5.7.23 | APARATOS SANITARIOS | 3d | 2015-12-17 | 2016-01-04 | 535 | 2015-12-11 | 2015-12-14 | 3d | 20d | 0d | CALENDARIO DE TRABAJO MONTERESERVA | 0% | 0% | 0% | 0% |
| 537 | 1.14.10 | DIVISIONES DE DUCHAS | 3d | 2016-01-04 | 2016-01-07 | 536 | 2015-12-15 | 2015-12-17 | 3d | 20d | 0d | CALENDARIO DE TRABAJO MONTERESERVA | 0% | 0% | 0% | 0% |
| 538 | 1.14.11 | ASEO PARA INSTALACION PISO | 2d | 2016-01-07 | 2016-01-09 | 537 | 2015-12-18 | 2015-12-19 | 2d | 20d | 0d | CALENDARIO DE TRABAJO MONTERESERVA | 0% | 0% | 0% | 0% |
| 539 | 1.14.12 | PRUEBA DE HUMEDAD | 2d | 2016-01-09 | 2016-01-13 | 538 | 2016-01-04 | 2016-01-05 | 2d | 20d | 8d | CALENDARIO DE TRABAJO MONTERESERVA | 0% | 0% | 0% | 0% |
| 540 | 1.5.4.15 | MUEBLE SALA Y CLÓSETS | 12d | 2015-12-17 | 2016-01-15 | 535 | 2015-12-11 | 2016-01-07 | 12d | 18d | 6d | CALENDARIO DE TRABAJO MONTERESERVA | 0% | 0% | 0% | 0% |
| 541 | 1.5.4.16 | MARCOS Y PUERTAS | 10d | 2016-01-13 | 2016-01-25 | 535, 515 | 2016-01-06 | 2016-01-18 | 10d | 10d | 0d | CALENDARIO DE TRABAJO MONTERESERVA | 0% | 0% | 0% | 0% |
| 542 | 1.5.4.17 | CARPINTERÍA COCINA Y BAÑOS | 8d | 2015-12-17 | 2016-01-09 | 535, 516 | 2015-12-11 | 2015-12-19 | 8d | 3d | 0d | CALENDARIO DE TRABAJO MONTERESERVA | 0% | 0% | 0% | 0% |
| 543 | 1.5.4.26 | PISO EN MADERA | 8d | 2016-01-25 | 2016-02-03 | 539, 540, 541, 542, 517 | 2016-01-19 | 2016-01-27 | 8d | 10d |  | CALENDARIO DE TRABAJO MONTERESERVA | 0% | 0% | 0% | 0% |
| 544 | 1.5.4.18 | MARMOL DUCHAS, MESÓN MARMOL Y MUEBLES COCINAS | 8d | 2016-01-09 | 2016-01-20 | 542 | 2016-01-04 | 2016-01-13 | 8d | 3d | 0d | CALENDARIO DE TRABAJO MONTERESERVA | 0% | 0% | 0% | 0% |
| 545 | 1.5.7.24 | GASODOMÉSTICOS | 2d | 2016-01-20 | 2016-01-22 | 544 | 2016-01-14 | 2016-01-15 | 2d | 3d | 2d | CALENDARIO DE TRABAJO MONTERESERVA | 0% | 0% | 0% | 0% |
| 546 | 1.14.19 | ESPEJOS BAÑOS | 2d | 2016-01-20 | 2016-01-22 | 544 | 2016-01-14 | 2016-01-15 | 2d | 3d | 0d | CALENDARIO DE TRABAJO MONTERESERVA | 0% | 0% | 0% | 0% |
| 547 | 1.5.4.25 | ASEO | 2d | 2016-01-22 | 2016-01-25 | 546 | 2016-01-16 | 2016-01-18 | 2d | 13d | 0d | CALENDARIO DE TRABAJO MONTERESERVA | 0% | 0% | 0% | 0% |
| 548 | 1.14.21 | INSTALACION GUARDAESCOBA | 5d | 2016-01-25 | 2016-01-30 | 547 | 2016-01-19 | 2016-01-23 | 5d | 13d |  | CALENDARIO DE TRABAJO MONTERESERVA | 0% | 0% | 0% | 0% |
| 549 | 1.14.22 | APARATOS ELECRICOS | 2d | 2016-01-20 | 2016-01-22 | 544 | 2016-01-14 | 2016-01-15 | 2d | 3d | 2d | CALENDARIO DE TRABAJO MONTERESERVA | 0% | 0% | 0% | 0% |
| 550 | 1.5.4.22 | PINTURA 3 | 8d | 2016-01-26 | 2016-02-04 | 545, 546, 549, 524 | 2016-01-20 | 2016-01-28 | 8d | 0d |  | CALENDARIO DE TRABAJO MONTERESERVA | 0% | 0% | 0% | 0% |
| 551 | 1.5.4.27 | ALFOMBRA | 3d | 2016-02-04 | 2016-02-08 | 550 | 2016-01-29 | 2016-02-01 | 3d | 0d |  | CALENDARIO DE TRABAJO MONTERESERVA | 0% | 0% | 0% | 0% |
| 552 | 1.5.4.28 | REVISIÓN FINAL Y ENTREGA | 6d | 2016-02-08 | 2016-02-15 | 551 | 2016-02-02 | 2016-02-08 | 6d | 0d |  | CALENDARIO DE TRABAJO MONTERESERVA | 0% | 0% | 0% | 0% |
